# G2P installation draft 7

Schedule from MS Project, 2011-05-16 to 2011-11-18.
JLAB

## Calendars

- Standard: Mon-Fri 08:00-12:00, 13:00-17:00; Sat-Sun off. Exceptions (off unless hours are given): 2011-05-30, 2011-07-04, 2011-09-05.

## Resources

| Resource |
| --- |
| Folts |
| Physics electronics group |
| Lumanog |
| Segal |
| Smith |
| Fansler |
| Ewing |
| ELECTRICIAN (TECH) |
| MECH ALIGN TECH |
| PLANT ENG |
| MECH INST TECH LITE |
| MECH VAC TECH |
| MSHOP |
| H-A MECH DES |
| ICD ELEC TECH |
| H-A MECH TECH |
| TARGET GROUP TECH |
| RADCON TECH |
| CRYO MECH ENG |
| Butler |
| Experimenters |
| OPS SOFTWARE |

## Schedule

| ID | WBS | Task | Type | Duration | Start | Finish | Predecessors | Total slack | Free slack | Constraint | Resources | Work | Text1 |
| --- | --- | --- | --- | --- | --- | --- | --- | --- | --- | --- | --- | --- | --- |
| 1 | 1 | **G2P installation** |  | 132d? | 2011-05-16 | 2011-11-18 |  | 0d |  |  |  | 4921h | XXXXXX |
| 2 | 1.1 | Radcon |  | 1d? | 2011-05-16 | 2011-05-16 |  | 131d |  |  | RADCON TECH | 8h |  |
| 3 | 1.2 | Alignment |  | 1d? | 2011-05-16 | 2011-05-16 |  | 131d |  |  | MECH ALIGN TECH | 8h |  |
| 4 | 1.3 | Engineering electronics or electrical |  | 1d? | 2011-05-16 | 2011-05-16 |  | 131d |  |  |  |  |  |
| 5 | 1.4 | Engineering mechanical |  | 1d? | 2011-05-16 | 2011-05-16 |  | 131d |  |  |  |  |  |
| 6 | 1.5 | engineering Vacuum |  | 1d? | 2011-05-16 | 2011-05-16 |  | 131d |  |  |  |  |  |
| 7 | 1.6 | Hall A techs or users |  | 1d? | 2011-05-16 | 2011-05-16 |  | 131d |  |  |  |  |  |
| 8 | 1.7 | target group |  | 1d? | 2011-05-16 | 2011-05-16 |  | 131d |  |  |  |  |  |
| 9 | 1.8 | Ops software |  | 1d? | 2011-05-16 | 2011-05-16 |  | 131d |  |  |  |  |  |
| 12 | 1.9 | **beam line prep work** |  | 39d? | 2011-05-16 | 2011-07-11 |  | 53d |  |  |  | 237h | XXXXXX |
| 13 | 1.9.1 | QA raster, calorimeter and magnet stands | milestone | 0d | 2011-05-16 | 2011-05-16 |  | 132d |  |  | H-A MECH TECH |  | SOT |
| 14 | 1.9.2 | install power for slow raster and calorimeter | milestone | 0d | 2011-05-16 | 2011-05-16 |  | 132d |  |  | H-A MECH TECH |  | SOT |
| 15 | 1.9.3 | install power in Hall for FZ magnets |  | 1d? | 2011-05-16 | 2011-05-16 |  | 131d |  |  | H-A MECH TECH | 8h |  |
| 16 | 1.9.4 | fab water manifolds for FZ magnets |  | 1d? | 2011-05-16 | 2011-05-16 |  | 131d |  |  | H-A MECH TECH | 8h |  |
| 17 | 1.9.5 | rework power connections for septum magnet |  | 1d? | 2011-05-16 | 2011-05-16 |  | 131d |  |  | H-A MECH TECH | 8h |  |
| 18 | 1.9.6 | rework water manifolds for septum magnet |  | 1d? | 2011-05-16 | 2011-05-16 |  | 131d |  |  | H-A MECH TECH | 8h |  |
| 19 | 1.9.7 | design and fab new electrical shields for septum magnet |  | 1d? | 2011-05-16 | 2011-05-16 |  | 131d |  |  | H-A MECH TECH | 8h |  |
| 20 | 1.9.8 | fab new beam pipe for septum magnet |  | 1d? | 2011-05-16 | 2011-05-16 |  | 131d |  |  | H-A MECH TECH | 8h |  |
| 21 | 1.9.9 | field map septum magnet |  | 1d? | 2011-05-16 | 2011-05-16 |  | 131d |  |  | MECH INST TECH LITE | 8h |  |
| 22 | 1.9.10 | pre survey beam dump |  | 1d? | 2011-05-16 | 2011-05-16 |  | 131d |  |  | MECH ALIGN TECH | 8h |  |
| 23 | 1.9.11 | pre survey target can |  | 1d? | 2011-05-16 | 2011-05-16 |  | 131d |  |  | MECH ALIGN TECH | 8h |  |
| 24 | 1.9.12 | pre survey target magnet |  | 1d? | 2011-05-16 | 2011-05-16 |  | 131d |  |  | MECH ALIGN TECH | 8h |  |
| 25 | 1.9.13 | close and unplug beam line vacuum valves |  | 1d? | 2011-05-16 | 2011-05-16 |  | 131d |  |  | MECH VAC TECH | 8h | SOT |
| 26 | 1.9.14 | turn off and valve off turbo pumps |  | 0.5d? | 2011-05-16 | 2011-05-16 |  | 131.5d |  |  | MECH VAC TECH | 4h | SOT |
| 27 | 1.9.15 | turn off diff pump station |  | 0.12d? | 2011-05-16 | 2011-05-16 |  | 131.88d |  |  | MECH VAC TECH | 1h | SOT |
| 28 | 1.9.16 | bleed up entrance beam line from diff pump to target |  | 0.5d? | 2011-05-16 | 2011-05-16 |  | 131.5d |  |  | MECH VAC TECH | 4h | SOT |
| 29 | 1.9.17 | reposition all metal beam line valve |  | 0.5d? | 2011-05-16 | 2011-05-16 |  | 131.5d |  |  | MECH VAC TECH | 4h | SOT |
| 30 | 1.9.18 | Target fiduc. 1.Mag:Top March 11 |  | 1d? | 2011-05-16 | 2011-05-16 |  | 131d |  |  | MECH ALIGN TECH | 8h |  |
| 31 | 1.9.19 | Target fiduc. 2.Top:Can Mar 11 |  | 1d? | 2011-05-16 | 2011-05-16 |  | 131d |  |  | MECH ALIGN TECH | 8h |  |
| 32 | 1.9.20 | Septa fiduc.(new locations) March 11 |  | 1d? | 2011-05-16 | 2011-05-16 |  | 131d |  |  | MECH ALIGN TECH | 8h |  |
| 33 | 1.9.21 | Platform - check target mount |  | 1d? | 2011-06-10 | 2011-06-10 |  | 113d |  | start no earlier than 2011-06-10 | MECH ALIGN TECH [200%] | 16h |  |
| 34 | 1.9.22 | Target top flange tube align |  | 1d? | 2011-06-10 | 2011-06-10 |  | 113d |  | start no earlier than 2011-06-10 | MECH ALIGN TECH [200%] | 16h |  |
| 35 | 1.9.23 | Target fiduc. 2.Top:Can |  | 1d? | 2011-07-11 | 2011-07-11 |  | 93d |  | start no earlier than 2011-07-11 | MECH ALIGN TECH [200%] | 16h |  |
| 36 | 1.9.24 | Dump / Sieve fid. |  | 1d? | 2011-07-11 | 2011-07-11 |  | 93d |  | start no earlier than 2011-07-11 | MECH ALIGN TECH [200%] | 16h |  |
| 38 | 1.9.25 | RadCon Hold |  | 5d | 2011-05-16 | 2011-05-20 |  | 53d | 0d |  | RADCON TECH | 40h | SOT |
| 39 | 1.9.26 | post beam checklist |  | 1d? | 2011-05-16 | 2011-05-16 | 38SS | 53d | 3d |  | H-A MECH TECH | 8h | SOT |

| ID | WBS | Task | Duration | Start | Finish | Predecessors | Total slack | Free slack | Constraint | Resources | Work | Text1 |
| --- | --- | --- | --- | --- | --- | --- | --- | --- | --- | --- | --- | --- |
| 41 | 1.10 | **LCW work** | 20d? | 2011-05-23 | 2011-06-20 |  | 107d |  |  |  | 160h | XXXXXX |
| 42 | 1.10.1 | install new manifold to facilitate FZ power supplies | 10d? | 2011-05-23 | 2011-06-06 | 39 | 107d | 0d | start no earlier than 2011-05-23 | H-A MECH TECH | 80h | SOT |
| 43 | 1.10.2 | install new manifolds to facilitate FZ magnets | 10d? | 2011-06-07 | 2011-06-20 | 42 | 107d |  | start no earlier than 2011-05-31 | H-A MECH TECH | 80h | SOT |
| 46 | 1.11 | **remove EP** | 10d? | 2011-05-23 | 2011-06-06 |  | 49d |  |  |  | 88h |  |
| 47 | 1.11.1 | Radcon coverage | 1d? | 2011-05-23 | 2011-05-23 | 39 | 49d | 0d | start no earlier than 2011-05-23 | RADCON TECH | 8h |  |
| 48 | 1.11.2 | disconnect cables | 1d? | 2011-05-23 | 2011-05-23 | 47SS | 49d | 0d | start no earlier than 2011-05-23 | H-A MECH TECH | 8h | SOT |
| 49 | 1.11.3 | remove external detectors | 1d? | 2011-05-24 | 2011-05-24 | 48 | 49d | 0d | start no earlier than 2011-05-24 | H-A MECH TECH | 8h | SOT |
| 50 | 1.11.4 | disconnect vacuum system | 1d? | 2011-05-25 | 2011-05-25 | 49 | 49d | 0d | start no earlier than 2011-03-16 | H-A MECH TECH | 8h | SOT |
| 51 | 1.11.5 | disconnect beam line | 1d? | 2011-05-26 | 2011-05-26 | 50 | 49d | 0d | start no earlier than 2011-03-17 | H-A MECH TECH | 8h | SOT |
| 52 | 1.11.6 | remove upper detector section | 1d? | 2011-05-27 | 2011-05-27 | 51 | 49d | 0d | start no earlier than 2011-03-18 | H-A MECH TECH | 8h |  |
| 53 | 1.11.7 | remove target section | 1d? | 2011-05-31 | 2011-05-31 | 52 | 49d | 0d | start no earlier than 2011-03-21 | H-A MECH TECH | 8h |  |
| 54 | 1.11.8 | remove lower detector system | 1d? | 2011-06-01 | 2011-06-01 | 53 | 49d | 0d | start no earlier than 2011-03-22 | H-A MECH TECH | 8h |  |
| 55 | 1.11.9 | remove EP stands | 1d? | 2011-06-02 | 2011-06-02 | 54 | 49d | 0d | start no earlier than 2011-03-23 | MECH INST TECH LITE | 8h |  |
| 56 | 1.11.10 | remove stand foundations | 1d? | 2011-06-03 | 2011-06-03 | 55 | 49d | 0d | start no earlier than 2011-03-24 | MECH INST TECH LITE | 8h | SOT |
| 57 | 1.11.11 | move EP system to ESB | 1d? | 2011-06-06 | 2011-06-06 | 56 | 117d |  | start no earlier than 2011-03-25 | H-A MECH TECH | 8h | SOT |
| 59 | 1.12 | **Compton maintenance** | 132d? | 2011-05-16 | 2011-11-18 |  | 0d |  |  |  | 4420h |  |
| 60 | 1.12.1 | Radcon hold | 1d? | 2011-07-05 | 2011-07-05 | 39 | 79d | 0d | start no earlier than 2011-07-05 | RADCON TECH | 8h | SOT |
| 61 | 1.12.2 | bleed up beam line | 1d? | 2011-07-05 | 2011-07-05 | 60SS | 79d | 0d | start no earlier than 2011-07-05 | MECH VAC TECH | 8h | SOT |
| 62 | 1.12.3 | remove blank flange for detector installation | 1d? | 2011-07-06 | 2011-07-06 | 61 | 79d | 0d |  | MECH VAC TECH | 8h | SOT |
| 63 | 1.12.4 | install electron detector package | 1d? | 2011-07-07 | 2011-07-07 | 62 | 79d | 0d | start no earlier than 2011-07-06 | MECH VAC TECH; MECH INST TECH LITE | 16h |  |
| 64 | 1.12.5 | pump down vacuum system | 2d? | 2011-07-08 | 2011-07-11 | 63 | 79d | 0d |  | MECH VAC TECH | 16h | SOT |
| 65 | 1.12.6 | leak check | 1d? | 2011-07-12 | 2011-07-12 | 64 | 79d | 0d |  | MECH VAC TECH | 8h | SOT |
| 66 | 1.12.7 | bake affected areas bleed up for maintenance | 1d? | 2011-07-13 | 2011-07-13 | 65 | 79d | 0d |  | MECH VAC TECH | 8h | SOT |
| 67 | 1.12.8 | connect electronics | 3d? | 2011-07-14 | 2011-07-18 | 66 | 79d | 0d |  | Experimenters | 24h | SOT |
| 68 | 1.12.9 | operational checkout of electronics | 9d? | 2011-07-19 | 2011-07-29 | 67 | 79d |  |  | Experimenters | 72h | SOT |
| 69 | 1.12.10 | open laser enclosure for work | 1d? | 2011-07-08 | 2011-07-08 |  | 87d | 0d | start no earlier than 2011-07-08 | Experimenters | 8h |  |
| 70 | 1.12.11 | replace laser mirrors | 5d? | 2011-07-11 | 2011-07-15 | 69 | 87d | 0d |  | Experimenters | 40h |  |
| 71 | 1.12.12 | align detector and laser as requested (to be defined later) | 2d? | 2011-07-18 | 2011-07-19 | 70 | 87d |  |  | MECH ALIGN TECH [200%] | 32h |  |

| ID | WBS | Task | Duration | Start | Finish | Predecessors | Total slack | Free slack | Constraint | Resources | Work | Text1 |
| --- | --- | --- | --- | --- | --- | --- | --- | --- | --- | --- | --- | --- |
| 73 | 1.12.13 | **install slow raster** | 42d? | 2011-06-06 | 2011-08-03 |  | 49d |  |  |  | 240h | XXXXXX |
| 74 | 1.12.13.1 | survey holes for stand | 2d? | 2011-06-06 | 2011-06-07 | 56 | 49d | 0d | start no earlier than 2011-06-06 | MECH ALIGN TECH [200%] | 32h | SOT |
| 75 | 1.12.13.2 | Drill holes | 2d? | 2011-06-08 | 2011-06-09 | 74 | 49d | 0d | start no earlier than 2011-03-15 | MECH INST TECH LITE | 16h | SOT |
| 76 | 1.12.13.3 | mount stand | 2d? | 2011-06-10 | 2011-06-13 | 75 | 49d | 0d | start no earlier than 2011-03-16 | MECH INST TECH LITE | 16h |  |
| 77 | 1.12.13.4 | survey stand | 2d? | 2011-06-14 | 2011-06-15 | 76 | 49d | 0d | start no earlier than 2011-03-17 | MECH ALIGN TECH [200%] | 32h | SOT |
| 78 | 1.12.13.5 | grout stand | 2d? | 2011-06-16 | 2011-06-17 | 77 | 97d | 0d | start no earlier than 2011-05-30 | MECH INST TECH LITE | 16h | SOT |
| 79 | 1.12.13.6 | grout set up time | 2d? | 2011-06-20 | 2011-06-21 | 78 | 97d | 0d | start no earlier than 2011-03-21 | MECH INST TECH LITE | 16h | SOT |
| 80 | 1.12.13.7 | install slow raster | 1d? | 2011-06-22 | 2011-06-22 | 79 | 97d | 0d | start no earlier than 2011-03-24 | MECH INST TECH LITE | 8h |  |
| 81 | 1.12.13.8 | pump down beam line | 2d? | 2011-06-24 | 2011-06-27 | 82, 80 | 97d | 0d | start no earlier than 2011-03-28 | MECH VAC TECH | 16h | SOT |
| 82 | 1.12.13.9 | connect beam line | 1d? | 2011-06-23 | 2011-06-23 | 80 | 97d | 0d | start no earlier than 2011-03-25 | MECH VAC TECH | 8h | SOT |
| 83 | 1.12.13.10 | survey slow raster | 2d? | 2011-06-28 | 2011-06-29 | 81, 82 | 97d | 0d | start no earlier than 2011-06-09 | MECH ALIGN TECH [200%] | 32h | SOT |
| 84 | 1.12.13.11 | install coils | 1d? | 2011-06-30 | 2011-06-30 | 83 | 97d | 0d | start no earlier than 2011-03-30 | Physics electronics group | 8h | SOT |
| 85 | 1.12.13.12 | install and connect raster controls and power | 1d? | 2011-07-01 | 2011-07-01 | 84 | 97d | 0d | start no earlier than 2011-03-31 | Physics electronics group | 8h | SOT |
| 86 | 1.12.13.13 | ops check slow raster | 1d? | 2011-07-05 | 2011-07-05 | 85 | 97d |  | start no earlier than 2011-04-01 | Physics electronics group | 8h | SOT |
| 87 | 1.12.13.14 | software checkout and ops check | 3d? | 2011-08-01 | 2011-08-03 |  | 76d |  | start no earlier than 2011-08-01 | OPS SOFTWARE | 24h |  |
| 89 | 1.12.14 | **install calorimeter** | 49d? | 2011-06-06 | 2011-08-12 |  | 69d |  |  |  | 248h | XXXXXX |
| 90 | 1.12.14.1 | survey holes for stand | 2d? | 2011-06-06 | 2011-06-07 | 56, 74SS | 97d | 0d | start no earlier than 2011-06-06 | MECH ALIGN TECH [200%] | 32h | SOT |
| 91 | 1.12.14.2 | Drill holes | 2d? | 2011-06-08 | 2011-06-09 | 90 | 97d | 0d | start no earlier than 2011-03-15 | MECH INST TECH LITE | 16h | SOT |
| 92 | 1.12.14.3 | mount stand | 2d? | 2011-06-10 | 2011-06-13 | 91 | 97d | 0d | start no earlier than 2011-03-16 | MECH INST TECH LITE | 16h |  |
| 93 | 1.12.14.4 | survey stand | 2d? | 2011-06-14 | 2011-06-15 | 92, 77SS | 97d | 0d | start no earlier than 2011-03-17 | MECH ALIGN TECH [200%] | 32h | SOT |
| 94 | 1.12.14.5 | grout stand | 2d? | 2011-06-16 | 2011-06-17 | 93 | 97d | 0d | start no earlier than 2011-05-30 | MECH INST TECH LITE | 16h | SOT |
| 95 | 1.12.14.6 | set up time | 2d? | 2011-06-20 | 2011-06-21 | 94 | 97d | 0d |  | MECH INST TECH LITE | 16h | SOT |
| 96 | 1.12.14.7 | install calorimeter | 1d? | 2011-06-22 | 2011-06-22 | 95 | 97d | 0d | start no earlier than 2011-06-22 | MECH INST TECH LITE | 8h |  |
| 97 | 1.12.14.8 | connect beam line | 1d? | 2011-06-23 | 2011-06-23 | 96 | 97d | 0d | start no earlier than 2011-03-25 | MECH VAC TECH | 8h |  |
| 98 | 1.12.14.9 | pump down beam line | 1d? | 2011-06-24 | 2011-06-24 | 97 | 97d | 0d | start no earlier than 2011-06-07 | MECH VAC TECH | 8h |  |
| 99 | 1.12.14.10 | leak check beam line | 1d? | 2011-06-27 | 2011-06-27 | 98 | 97d | 0d |  | MECH VAC TECH | 8h | SOT |
| 100 | 1.12.14.11 | connect motion and cooling lines | 1d? | 2011-06-28 | 2011-06-28 | 99 | 97d | 0d | start no earlier than 2011-06-09 | MECH INST TECH LITE | 8h |  |
| 101 | 1.12.14.12 | survey calorimeter | 1d? | 2011-06-29 | 2011-06-29 | 100, 83SS | 97d | 2d | start no earlier than 2011-06-10 | MECH ALIGN TECH [200%] | 16h | SOT |
| 102 | 1.12.14.13 | install controls | 2d? | 2011-07-05 | 2011-07-06 | 101 | 95d | 0d | start no earlier than 2011-07-05 | ICD ELEC TECH | 16h |  |
| 103 | 1.12.14.14 | ops check | 1d? | 2011-07-07 | 2011-07-07 | 102 | 95d |  | start no earlier than 2011-07-06 | ICD ELEC TECH | 8h | SOT |
| 104 | 1.12.14.15 | software checkout and ops check | 5d? | 2011-08-08 | 2011-08-12 |  | 69d |  | start no earlier than 2011-08-08 | OPS SOFTWARE | 40h |  |

| ID | WBS | Task | Duration | Start | Finish | Predecessors | Total slack | Free slack | Constraint | Resources | Work | Text1 |
| --- | --- | --- | --- | --- | --- | --- | --- | --- | --- | --- | --- | --- |
| 106 | 1.12.15 | **remove dual quads & short girder** | 25d? | 2011-07-07 | 2011-08-10 |  | 71d |  |  |  | 216h | XXXXXX |
| 107 | 1.12.15.1 | Radcon support | 1d? | 2011-07-07 | 2011-07-07 |  | 72.5d | 0d | start no earlier than 2011-07-07 |  |  |  |
| 108 | 1.12.15.2 | disconnect water and power on dual quad assembly | 1d? | 2011-07-07 | 2011-07-07 | 107SS, 39 | 72.5d | 0d | start no earlier than 2011-07-07 | MECH INST TECH LITE | 8h | SOT |
| 109 | 1.12.15.3 | bleed up vacuum | 1d? | 2011-07-08 | 2011-07-08 | 108 | 72.5d | 0d |  | MECH VAC TECH | 8h | SOT |
| 110 | 1.12.15.4 | disconnect vacuum lines | 2d? | 2011-07-11 | 2011-07-12 | 109 | 72.5d | 0d | start no earlier than 2011-03-15 | MECH VAC TECH | 16h | SOT |
| 111 | 1.12.15.5 | remove quad girder | 1d? | 2011-07-13 | 2011-07-13 | 110 | 72.5d | 0d | start no earlier than 2011-03-16 | MECH INST TECH LITE | 8h |  |
| 112 | 1.12.15.6 | remove lead from 3 inch beam line | 1d? | 2011-07-14 | 2011-07-14 | 111 | 72.5d | 0d |  | MECH INST TECH LITE | 8h |  |
| 113 | 1.12.15.7 | install new 3 inch beam line | 1d? | 2011-07-15 | 2011-07-15 | 112 | 72.5d | 0d |  | MECH VAC TECH | 8h |  |
| 114 | 1.12.15.8 | install beam line and corrector support girder | 1d? | 2011-07-18 | 2011-07-18 | 113 | 72.5d | 0d | start no earlier than 2011-06-23 | MECH INST TECH LITE | 8h | SOT |
| 115 | 1.12.15.9 | install controls and power cabling | 4d? | 2011-07-19 | 2011-07-22 | 114 | 72.5d | 0d |  | ICD ELEC TECH | 32h |  |
| 116 | 1.12.15.10 | install BLM | 1d? | 2011-07-25 | 2011-07-25 | 115 | 72.5d | 0d |  | ICD ELEC TECH | 8h | SOT |
| 117 | 1.12.15.11 | install controls | 2d? | 2011-07-26 | 2011-07-27 | 116 | 72.5d | 0d |  | ICD ELEC TECH | 16h |  |
| 118 | 1.12.15.12 | connect beam line | 1d? | 2011-07-28 | 2011-07-28 | 117 | 72.5d | 0d | start no earlier than 2011-06-27 | MECH VAC TECH | 8h |  |
| 119 | 1.12.15.13 | install vacuum pump and controls | 3d? | 2011-07-29 | 2011-08-02 | 118 | 72.5d | 0d | start no earlier than 2011-03-17 | MECH VAC TECH | 24h |  |
| 120 | 1.12.15.14 | pump down and leak check girder | 2d | 2011-08-03 | 2011-08-04 | 119 | 72.5d | 0d |  | MECH VAC TECH | 16h |  |
| 121 | 1.12.15.15 | survey beam line | 1d? | 2011-08-05 | 2011-08-05 | 120 | 72.5d | 0d | start no earlier than 2011-03-18 | MECH ALIGN TECH [200%] | 16h |  |
| 122 | 1.12.15.16 | reinstall lead removed for 3 inch beam pipe | 1d? | 2011-08-10 | 2011-08-10 | 121 | 71d |  | start no earlier than 2011-08-10 | MECH INST TECH LITE | 8h |  |
| 123 | 1.12.15.17 | ops check | 1.5d? | 2011-08-08 | 2011-08-09 | 121 | 72.5d |  | start no earlier than 2011-08-03 | MECH VAC TECH; ICD ELEC TECH | 24h | SOT |
| 125 | 1.12.16 | **remove girder** | 8d? | 2011-05-23 | 2011-06-02 |  | 50d |  |  |  | 112h | XXXXXX |
| 126 | 1.12.16.1 | Radcon support | 1d? | 2011-05-23 | 2011-05-23 |  | 50d | 0d | start no earlier than 2011-05-23 | RADCON TECH | 8h |  |
| 127 | 1.12.16.2 | remove lead shielding | 5d? | 2011-05-23 | 2011-05-27 | 126SS | 122d |  | start no earlier than 2011-05-23 | MECH INST TECH LITE | 40h |  |
| 128 | 1.12.16.3 | disconnect beam line diagnostics | 1d? | 2011-05-23 | 2011-05-23 | 126SS | 50d | 0d | start no earlier than 2011-05-23 | ICD ELEC TECH | 8h |  |
| 129 | 1.12.16.4 | disconnect vacuum equipment | 2d? | 2011-05-24 | 2011-05-25 | 128 | 50d | 0d | start no earlier than 2011-03-15 | MECH VAC TECH | 16h | SOT |
| 130 | 1.12.16.5 | remove water and control lines | 2d? | 2011-05-26 | 2011-05-27 | 129 | 50d | 0d | start no earlier than 2011-03-18 | MECH INST TECH LITE | 16h | SOT |
| 131 | 1.12.16.6 | remove girder | 1d? | 2011-05-31 | 2011-05-31 | 130 | 50d | 0d | start no earlier than 2011-03-21 | MECH INST TECH LITE | 8h |  |
| 132 | 1.12.16.7 | remove girder stands | 1d? | 2011-06-01 | 2011-06-01 | 131 | 50d | 0d | start no earlier than 2011-03-22 | MECH INST TECH LITE | 8h |  |
| 133 | 1.12.16.8 | remove stand grout | 1d? | 2011-06-02 | 2011-06-02 | 132 | 50d | 1d | start no earlier than 2011-03-23 | MECH INST TECH LITE | 8h |  |

| ID | WBS | Task | Type | Duration | Start | Finish | Predecessors | Total slack | Free slack | Constraint | Resources | Work | Text1 |
| --- | --- | --- | --- | --- | --- | --- | --- | --- | --- | --- | --- | --- | --- |
| 135 | 1.12.17 | **install FZ magnets** |  | 122d? | 2011-05-16 | 2011-11-04 |  | 10d |  |  |  | 704h | XXXXXX |
| 136 | 1.12.17.1 | survey holes for stands |  | 2d? | 2011-06-06 | 2011-06-07 | 133, 74SS | 49d | 0d | start no earlier than 2011-06-06 | MECH ALIGN TECH [200%] | 32h | SOT |
| 137 | 1.12.17.2 | Drill holes |  | 2d? | 2011-06-08 | 2011-06-09 | 136 | 49d | 0d | start no earlier than 2011-03-15 | MECH INST TECH LITE | 16h | SOT |
| 138 | 1.12.17.3 | mount stands |  | 2d? | 2011-06-10 | 2011-06-13 | 137 | 49d | 0d | start no earlier than 2011-03-16 | MECH INST TECH LITE | 16h |  |
| 139 | 1.12.17.4 | survey stands |  | 2d? | 2011-06-14 | 2011-06-15 | 138, 77SS | 49d | 0d | start no earlier than 2011-03-17 | MECH ALIGN TECH [200%] | 32h | SOT |
| 140 | 1.12.17.5 | grout stands |  | 2d? | 2011-06-16 | 2011-06-17 | 139 | 49d | 0d | start no earlier than 2011-03-18 | MECH INST TECH LITE | 16h | SOT |
| 141 | 1.12.17.6 | grout set up time |  | 2d? | 2011-06-20 | 2011-06-21 | 140 | 49d | 29d | start no earlier than 2011-03-21 | MECH INST TECH LITE | 16h | SOT |
| 142 | 1.12.17.7 | install cable tray |  | 3d? | 2011-08-03 | 2011-08-05 | 141 | 20d | 0d | start no earlier than 2011-08-03 | H-A MECH TECH | 24h |  |
| 143 | 1.12.17.8 | run magnet power cables |  | 2d? | 2011-08-08 | 2011-08-09 | 142 | 20d | 0d |  | H-A MECH TECH | 16h |  |
| 144 | 1.12.17.9 | run instrumentation cables |  | 2d? | 2011-08-10 | 2011-08-11 | 143 | 20d | 0d |  | ICD ELEC TECH | 16h |  |
| 145 | 1.12.17.10 | connect AC power to power supplies |  | 2d? | 2011-08-12 | 2011-08-15 | 144 | 20d | 0d |  | ELECTRICIAN (TECH) | 16h | SOT |
| 147 | 1.12.17.11 | install FZ magnets |  | 10d? | 2011-08-16 | 2011-08-29 | 145 | 20d | 0d | start no earlier than 2011-03-24 | MECH INST TECH LITE | 80h |  |
| 148 | 1.12.17.12 | survey FZ magnets |  | 4d? | 2011-08-30 | 2011-09-02 | 147 | 20d | 0d |  | MECH ALIGN TECH [200%] | 64h |  |
| 149 | 1.12.17.13 | install and connect DC power to magnets |  | 1d? | 2011-09-06 | 2011-09-06 | 148 | 20d | 0d |  | ICD ELEC TECH | 8h |  |
| 150 | 1.12.17.14 | ops check magnets |  | 5d? | 2011-09-07 | 2011-09-13 | 149 | 20d | 0d |  | ICD ELEC TECH | 40h |  |
| 151 | 1.12.17.15 | install FZ beam line supports |  | 3d? | 2011-09-14 | 2011-09-16 | 150 | 20d | 0d | start no earlier than 2011-03-31 | MECH INST TECH LITE | 24h |  |
| 152 | 1.12.17.16 | install beam lines and beam diagnostics |  | 5d? | 2011-09-19 | 2011-09-23 | 151 | 20d | 0d | start no earlier than 2011-04-05 | MECH VAC TECH | 40h | SOT |
| 153 | 1.12.17.17 | install vacuum system |  | 5d? | 2011-09-26 | 2011-09-30 | 152 | 20d | 0d | start no earlier than 2011-04-28 | MECH VAC TECH | 40h | SOT |
| 154 | 1.12.17.18 | reposition all metal valve |  | 1d? | 2011-10-03 | 2011-10-03 | 153 | 20d | 0d | start no earlier than 2011-05-05 | MECH VAC TECH | 8h | SOT |
| 155 | 1.12.17.19 | install instrumentation |  | 4d? | 2011-10-04 | 2011-10-07 | 154 | 20d | 0d | start no earlier than 2011-05-06 | ICD ELEC TECH | 32h | SOT |
| 156 | 1.12.17.20 | pump down beam line |  | 2d? | 2011-10-10 | 2011-10-11 | 155 | 20d | 0d | start no earlier than 2011-05-12 | MECH VAC TECH | 16h | SOT |
| 157 | 1.12.17.21 | leak check beam lines |  | 2d? | 2011-10-12 | 2011-10-13 | 156 | 20d | 0d | start no earlier than 2011-05-16 | MECH VAC TECH | 16h | SOT |
| 158 | 1.12.17.22 | survey beam lines |  | 3d | 2011-10-14 | 2011-10-18 | 157 | 20d | 0d | start no earlier than 2011-05-18 | MECH ALIGN TECH [200%] | 48h | SOT |
| 159 | 1.12.17.23 | ops check |  | 3d? | 2011-10-19 | 2011-10-21 | 158 | 20d |  | start no earlier than 2011-05-19 | MECH VAC TECH; ICD ELEC TECH | 48h | SOT |
| 160 | 1.12.17.24 | software checkout and ops check |  | 5d? | 2011-10-31 | 2011-11-04 |  | 10d |  | start no earlier than 2011-10-31 | OPS SOFTWARE | 40h |  |
| 209 | 1.12.17.25 | Hall A from here down | milestone | 0d? | 2011-05-16 | 2011-05-16 |  | 132d |  |  |  |  |  |

| ID | WBS | Task | Type | Duration | Start | Finish | Predecessors | Total slack | Free slack | Constraint | Resources | Work | Text1 |
| --- | --- | --- | --- | --- | --- | --- | --- | --- | --- | --- | --- | --- | --- |
| 211 | 1.12.18 | **target / septa prep work** |  | 0d | 2011-05-16 | 2011-05-16 |  | 132d |  |  |  |  | XXXXXX |
| 212 | 1.12.18.1 | modify septa platform | milestone | 0d | 2011-05-16 | 2011-05-16 |  | 132d |  |  |  |  | SOT |
| 213 | 1.12.18.2 | install 3rd coil set in septum magnet | milestone | 0d | 2011-05-16 | 2011-05-16 |  | 132d |  |  |  |  | SOT |
| 214 | 1.12.18.3 | pre assemble align target support on septa platform | milestone | 0d | 2011-05-16 | 2011-05-16 |  | 132d |  |  |  |  | SOT |
| 216 | 1.12.19 | **cryo work** |  | 86.5d? | 2011-05-16 | 2011-09-16 |  | 45.5d |  |  |  | 556h | XXXXXX |
| 217 | 1.12.19.1 | warm up both spectrometers |  | 5d? | 2011-05-16 | 2011-05-20 |  | 85.25d | 5d |  | H-A MECH TECH; Fansler | 80h | SOT |
| 218 | 1.12.19.2 | pump all magnets |  | 5d? | 2011-05-31 | 2011-06-06 | 217 | 80.25d | 4d | start no earlier than 2011-05-31 | Fansler; H-A MECH TECH | 80h | SOT |
| 219 | 1.12.19.3 | pump all cryo lines |  | 5d? | 2011-06-13 | 2011-06-17 | 218 | 76.25d | 5d | start no earlier than 2011-06-13 | Fansler; H-A MECH TECH | 80h |  |
| 220 | 1.12.19.4 | replace Q1 JT valve heads with JLab valves |  | 5d? | 2011-06-27 | 2011-07-01 | 219 | 71.25d | 0d | start no earlier than 2011-06-27 | Fansler; H-A MECH TECH | 80h | SOT |
| 221 | 1.12.19.5 | replace dipole LN2 probes |  | 1d? | 2011-07-05 | 2011-07-05 | 220 | 71.25d | 1d | start no earlier than 2011-07-05 | Fansler; H-A MECH TECH | 16h | SOT |
| 222 | 1.12.19.6 | replace magnet pressure gauges |  | 2.5d? | 2011-07-07 | 2011-07-11 | 221 | 70.25d | 2.5d | start no earlier than 2011-07-07 | Fansler; H-A MECH TECH | 40h | SOT |
| 223 | 1.12.19.7 | repair left Q1 leads |  | 5d? | 2011-07-14 | 2011-07-20 | 222 | 67.75d | 5d | start no earlier than 2011-07-14 | Fansler; H-A MECH TECH | 80h | SOT |
| 224 | 1.12.19.8 | replace left Q1 vacuum seals |  | 3.75d? | 2011-07-28 | 2011-08-02 | 223 | 62.75d | 1.25d | start no earlier than 2011-07-28 | Fansler; H-A MECH TECH | 60h | SOT |
| 225 | 1.12.19.9 | replace all Q1 110 vac plugs due to radiation damage |  | 2.5d? | 2011-08-04 | 2011-08-08 | 224 | 61.5d | 4.5d | start no earlier than 2011-08-04 | Fansler; H-A MECH TECH | 40h | SOT |
| 226 | 1.12.19.10 | calibrate Ln2 ll probes |  | 2.5d? | 2011-08-15 | 2011-08-17 | 225 | 57d | 7.5d | start no earlier than 2011-08-15 |  |  |  |
| 227 | 1.12.19.11 | Calibrate weha valves |  | 5d? | 2011-08-29 | 2011-09-02 | 226 | 49.5d | 4d | start no earlier than 2011-08-29 |  |  |  |
| 228 | 1.12.19.12 | repair dipole He LL probe |  | 4.5d? | 2011-09-12 | 2011-09-16 | 227 | 45.5d |  | start no earlier than 2011-09-12 |  |  |  |
| 230 | 1.12.20 | **Detector work** |  | 39d? | 2011-06-06 | 2011-07-29 |  | 79d |  |  |  | 304h | XXXXXX |
| 231 | 1.12.20.1 | roll out left detector |  | 1d? | 2011-06-06 | 2011-06-06 |  | 101d | 4d | start no earlier than 2011-06-06 | Segal; H-A MECH TECH | 16h | SOT |
| 232 | 1.12.20.2 | pull out SRC detectors |  | 2d? | 2011-06-13 | 2011-06-14 | 231 | 97d | 3d | start no earlier than 2011-06-13 | Segal; H-A MECH TECH | 32h |  |
| 233 | 1.12.20.3 | install G2P detectors |  | 5d? | 2011-06-20 | 2011-06-24 | 232 | 94d | 0d | start no earlier than 2011-06-20 | Segal; H-A MECH TECH | 80h |  |
| 234 | 1.12.20.4 | roll in left detector |  | 1d? | 2011-06-27 | 2011-06-27 | 233 | 102d |  | start no earlier than 2011-05-31 | Segal; H-A MECH TECH | 16h | SOT |
| 235 | 1.12.20.5 | clear balcony and close doors |  | 1d? | 2011-06-29 | 2011-06-29 | 233 | 92d | 2d | start no earlier than 2011-06-29 | Segal; H-A MECH TECH | 16h |  |
| 237 | 1.12.20.6 | roll out right detector |  | 1d? | 2011-07-05 | 2011-07-05 | 235 | 90d | 3d | start no earlier than 2011-07-05 | Segal; H-A MECH TECH | 16h | SOT |
| 238 | 1.12.20.7 | pull out SRC detectors |  | 2d? | 2011-07-11 | 2011-07-12 | 237 | 87d | 3d | start no earlier than 2011-07-11 | Segal; H-A MECH TECH | 32h |  |
| 239 | 1.12.20.8 | install G2P detectors |  | 4d? | 2011-07-18 | 2011-07-21 | 238 | 84d | 1d | start no earlier than 2011-07-18 | Segal; H-A MECH TECH | 64h |  |
| 240 | 1.12.20.9 | roll in left detector |  | 1d? | 2011-07-25 | 2011-07-25 | 239 | 83d |  | start no earlier than 2011-07-25 | Segal; H-A MECH TECH | 16h | SOT |
| 241 | 1.12.20.10 | clear balcony and close doors |  | 1d? | 2011-07-29 | 2011-07-29 | 239 | 79d |  | start no earlier than 2011-07-29 | Segal; H-A MECH TECH | 16h |  |

| ID | WBS | Task | Duration | Start | Finish | Predecessors | Total slack | Free slack | Constraint | Resources | Work | Text1 |
| --- | --- | --- | --- | --- | --- | --- | --- | --- | --- | --- | --- | --- |
| 243 | 1.12.21 | **remove target** | 37d? | 2011-05-16 | 2011-07-07 |  | 26d |  |  |  | 600h | XXXXXX |
| 244 | 1.12.21.1 | warm up target | 4d? | 2011-05-16 | 2011-05-19 |  | 104.5d | 0d |  | TARGET GROUP TECH | 32h | SOT |
| 245 | 1.12.21.2 | Radcon support | 1d? | 2011-05-20 | 2011-05-20 | 244 | 104.5d | 0d | start no earlier than 2011-05-20 | RADCON TECH | 8h |  |
| 246 | 1.12.21.3 | bleed up chamber | 1d? | 2011-05-20 | 2011-05-20 | 245SS | 104.5d | 0d | start no earlier than 2011-03-17 | H-A MECH TECH | 8h | SOT |
| 247 | 1.12.21.4 | de-sting cryo | 1d? | 2011-05-23 | 2011-05-23 | 246 | 104.5d | 0d | start no earlier than 2011-03-18 | TARGET GROUP TECH | 8h |  |
| 248 | 1.12.21.5 | disconnect target | 8d? | 2011-05-24 | 2011-06-03 | 247 | 104.5d | 0d | start no earlier than 2011-03-21 | TARGET GROUP TECH | 64h | SOT |
| 249 | 1.12.21.6 | remove target from chamber | 1d? | 2011-06-06 | 2011-06-06 | 248 | 104.5d | 0d | start no earlier than 2011-03-28 | H-A MECH TECH; TARGET GROUP TECH | 16h |  |
| 250 | 1.12.21.7 | remove vacuum system | 1d? | 2011-06-07 | 2011-06-07 | 249 | 104.5d | 0d | start no earlier than 2011-03-29 | H-A MECH TECH | 8h | SOT |
| 251 | 1.12.21.8 | remove beam pipes | 1d? | 2011-06-08 | 2011-06-08 | 250 | 104.5d | 0d | start no earlier than 2011-03-30 | H-A MECH TECH | 8h | SOT |
| 252 | 1.12.21.9 | remove upper chamber | 1d? | 2011-06-09 | 2011-06-09 | 251 | 104.5d | 0d | start no earlier than 2011-03-31 | H-A MECH TECH | 8h |  |
| 253 | 1.12.21.10 | remove lower chamber | 1d? | 2011-06-10 | 2011-06-10 | 252 | 104.5d | 0d | start no earlier than 2011-04-01 | H-A MECH TECH | 8h |  |
| 254 | 1.12.21.11 | remove chamber support spool | 1d? | 2011-06-13 | 2011-06-13 | 253 | 104.5d | 0d | start no earlier than 2011-06-13 | H-A MECH TECH | 8h |  |
| 255 | 1.12.21.12 | reconfigure target lines and cables for new target | 7.5d? | 2011-06-14 | 2011-06-23 | 254 | 104.5d |  | start no earlier than 2011-06-13 | TARGET GROUP TECH; H-A MECH TECH | 120h | SOT |
| 257 | 1.12.21.13 | **remove Big Bite** | 37d? | 2011-05-16 | 2011-07-07 |  | 26d |  |  |  | 304h | XXXXXX |
| 258 | 1.12.21.13.1 | Radcon Support | 1d? | 2011-05-16 | 2011-05-16 |  | 114d | 0d |  | RADCON TECH | 8h |  |
| 259 | 1.12.21.13.2 | disconnect BB detector | 5d? | 2011-05-16 | 2011-05-20 | 258SS | 114d | 0d | start no earlier than 2011-05-16 | H-A MECH TECH | 40h | SOT |
| 260 | 1.12.21.13.3 | disconnect water | 1d? | 2011-05-23 | 2011-05-23 | 259 | 114d | 0d | start no earlier than 2011-05-23 | H-A MECH TECH | 8h | SOT |
| 261 | 1.12.21.13.4 | disconnect and move inst. Interlocks etc | 2d? | 2011-05-24 | 2011-05-25 | 260 | 114d | 0d | start no earlier than 2011-03-15 | H-A MECH TECH | 16h | SOT |
| 262 | 1.12.21.13.5 | disconnect BB power | 2d? | 2011-05-26 | 2011-05-27 | 261 | 114d | 0d | start no earlier than 2011-05-18 | H-A MECH TECH | 16h | SOT |
| 263 | 1.12.21.13.6 | install extension rails on BB stand | 1d? | 2011-05-31 | 2011-05-31 | 262 | 114d | 1d | start no earlier than 2011-05-19 | H-A MECH TECH | 8h |  |
| 264 | 1.12.21.13.7 | reroute BB power lines for septum | 2d? | 2011-06-02 | 2011-06-03 | 263 | 113d | 0d | start no earlier than 2011-06-02 | H-A MECH TECH | 16h |  |
| 265 | 1.12.21.13.8 | role back detector platform | 1d? | 2011-06-06 | 2011-06-06 | 264 | 113d | 0d | start no earlier than 2011-06-06 | H-A MECH TECH | 8h | SOT |
| 266 | 1.12.21.13.9 | rig and move detector | 1d? | 2011-06-07 | 2011-06-07 | 265 | 113d | 0d | start no earlier than 2011-06-07 | H-A MECH TECH | 8h |  |
| 267 | 1.12.21.13.10 | remove detector platform | 1d? | 2011-06-08 | 2011-06-08 | 266 | 113d | 0d | start no earlier than 2011-03-18 | H-A MECH TECH | 8h |  |
| 268 | 1.12.21.13.11 | partial rollback of BB for field clamp removal | 1d? | 2011-06-09 | 2011-06-09 | 267 | 113d | 0d | start no earlier than 2011-06-09 | H-A MECH TECH | 8h | SOT |
| 269 | 1.12.21.13.12 | rig and move field clamp including collimator to storage position | 1d? | 2011-06-10 | 2011-06-10 | 268 | 113d |  | start no earlier than 2011-06-10 | H-A MECH TECH | 8h |  |
| 270 | 1.12.21.13.13 | rollback BB for door removal | 1d? | 2011-06-13 | 2011-06-13 |  | 7d | 0d | start no earlier than 2011-06-13 | H-A MECH TECH | 8h | SOT |
| 271 | 1.12.21.13.14 | remove shielding doors to storage position | 2d? | 2011-06-14 | 2011-06-15 | 270 | 7d | 0d | start no earlier than 2011-03-22 | H-A MECH TECH | 16h |  |
| 272 | 1.12.21.13.15 | remove shielding on top and around BB | 2d? | 2011-06-16 | 2011-06-17 | 271 | 7d | 0d | start no earlier than 2011-03-23 | H-A MECH TECH | 16h |  |
| 273 | 1.12.21.13.16 | install pink stand | 1d? | 2011-06-20 | 2011-06-20 | 272 | 7d | 0d | start no earlier than 2011-03-24 | H-A MECH TECH | 8h |  |
| 274 | 1.12.21.13.17 | Add supports to BB feet | 1d? | 2011-06-21 | 2011-06-21 | 273 | 7d | 0d | start no earlier than 2011-06-17 | H-A MECH TECH | 8h | SOT |
| 275 | 1.12.21.13.18 | remove feet from BB | 1d? | 2011-06-22 | 2011-06-22 | 274 | 7d | 0d | start no earlier than 2011-06-20 | H-A MECH TECH | 8h |  |
| 276 | 1.12.21.13.19 | rig and move BB magnet to storage position | 2d? | 2011-06-23 | 2011-06-24 | 275 | 7d | 0d | start no earlier than 2011-06-21 | H-A MECH TECH | 16h |  |
| 277 | 1.12.21.13.20 | rig feet and move to storage position | 1d? | 2011-06-27 | 2011-06-27 | 276 | 7d | 0d | start no earlier than 2011-06-22 | H-A MECH TECH | 8h |  |
| 278 | 1.12.21.13.21 | reposition rollers and other support equipment to storage position | 1d? | 2011-06-28 | 2011-06-28 | 277 | 7d | 0d | start no earlier than 2011-06-23 | H-A MECH TECH | 8h |  |
| 279 | 1.12.21.13.22 | remove rail extensions | 1d? | 2011-06-29 | 2011-06-29 | 278 | 7d | 0d | start no earlier than 2011-06-24 | H-A MECH TECH | 8h |  |
| 280 | 1.12.21.13.23 | remove pink stand | 1d? | 2011-06-30 | 2011-06-30 | 279 | 7d | 0d | start no earlier than 2011-06-27 | H-A MECH TECH | 8h |  |
| 281 | 1.12.21.13.24 | rig and move BB stand | 1d? | 2011-07-01 | 2011-07-01 | 280 | 7d | 0d | start no earlier than 2011-06-28 | H-A MECH TECH | 8h |  |
| 282 | 1.12.21.13.25 | Rotate right spect. To 12.5 degrees | 1d? | 2011-07-05 | 2011-07-05 | 281 | 7d | 0d | start no earlier than 2011-06-29 | H-A MECH TECH | 8h | SOT |
| 283 | 1.12.21.13.26 | Radcon support | 1d? | 2011-07-06 | 2011-07-06 |  | 95d | 0d | start no earlier than 2011-07-06 | RADCON TECH | 8h |  |
| 284 | 1.12.21.13.27 | move electronics to storage | 1d? | 2011-07-06 | 2011-07-06 | 282, 283SS | 95d | 0d | start no earlier than 2011-06-30 | H-A MECH TECH | 8h |  |
| 285 | 1.12.21.13.28 | move Hadron detector frame to PSB | 1d? | 2011-07-07 | 2011-07-07 | 284 | 95d |  | start no earlier than 2011-07-06 | H-A MECH TECH | 8h |  |

| ID | WBS | Task | Type | Duration | Start | Finish | Predecessors | Total slack | Free slack | Constraint | Resources | Work | Text1 |
| --- | --- | --- | --- | --- | --- | --- | --- | --- | --- | --- | --- | --- | --- |
| 287 | 1.12.22 | **install septum and target** |  | 42d? | 2011-07-05 | 2011-09-01 |  | 1d |  |  |  | 408h | XXXXXX |
| 288 | 1.12.22.1 | install septum support stand |  | 2d? | 2011-07-05 | 2011-07-06 | 282SS | 7d | 0d | start no earlier than 2011-07-04 | H-A MECH TECH | 16h |  |
| 289 | 1.12.22.2 | align stand with laser |  | 1d? | 2011-07-07 | 2011-07-07 | 288 | 7d | 0d | start no earlier than 2011-06-09 | H-A MECH TECH | 8h | SOT |
| 290 | 1.12.22.3 | install beam right access platform and stairs |  | 1d? | 2011-07-08 | 2011-07-08 | 289 | 7d | 0d | start no earlier than 2011-06-10 | H-A MECH TECH | 8h |  |
| 291 | 1.12.22.4 | RadCon Hold |  | 5d? | 2011-07-11 | 2011-07-15 | 290 | 7d | 0d | start no earlier than 2011-07-11 | RADCON TECH | 40h | SOT |
| 292 | 1.12.22.5 | install septum platform on support stand |  | 1d? | 2011-07-11 | 2011-07-11 | 291SS | 7d | 0d | start no earlier than 2011-06-13 | H-A MECH TECH | 8h |  |
| 293 | 1.12.22.6 | install septum magnet on platform |  | 1d? | 2011-07-12 | 2011-07-12 | 292 | 7d | 0d | start no earlier than 2011-06-14 | H-A MECH TECH | 8h |  |
| 294 | 1.12.22.7 | install tread plated and dump support on platform |  | 1d? | 2011-07-13 | 2011-07-13 | 293 | 7d | 0d | start no earlier than 2011-06-15 | H-A MECH TECH | 8h |  |
| 295 | 1.12.22.8 | pre alignment of septum magnet |  | 1d? | 2011-07-14 | 2011-07-14 | 294 | 7d | 0d | start no earlier than 2011-06-16 | H-A MECH TECH [200%] | 16h | SOT |
| 296 | 1.12.22.9 | install beam dump between magnet and target |  | 2d? | 2011-07-15 | 2011-07-18 | 295 | 7d | 0d | start no earlier than 2011-06-21 | H-A MECH TECH | 16h |  |
| 297 | 1.12.22.10 | install target chamber support on platform |  | 1d? | 2011-07-19 | 2011-07-19 | 296, 295 | 7d | 0d | start no earlier than 2011-06-17 | H-A MECH TECH | 8h |  |
| 298 | 1.12.22.11 | pre align beam dump with laser |  | 1d? | 2011-07-20 | 2011-07-20 | 297 | 7d | 2d |  |  |  |  |
| 299 | 1.12.22.12 | RadCon Hold |  | 2d? | 2011-07-25 | 2011-07-26 | 298 | 5d | 1d | start no earlier than 2011-07-25 | RADCON TECH | 16h | SOT |
| 300 | 1.12.22.13 | install exit beam pipe in magnet |  | 1d? | 2011-07-26 | 2011-07-26 | 299SS | 4d | 0d | start no earlier than 2011-07-26 | H-A MECH TECH | 8h | SOT |
| 301 | 1.12.22.14 | install shielding between target and magnet |  | 2d? | 2011-07-27 | 2011-07-28 | 300 | 4d | 0d | start no earlier than 2011-07-27 | H-A MECH TECH; TARGET GROUP TECH | 32h |  |
| 302 | 1.12.22.15 | install target chamber into chamber support |  | 1d? | 2011-07-29 | 2011-07-29 | 301 | 4d | 0d | start no earlier than 2011-06-23 | H-A MECH TECH; TARGET GROUP TECH | 16h |  |
| 303 | 1.12.22.16 | roll septum/target platform into position |  | 1d? | 2011-08-01 | 2011-08-01 | 302 | 4d | 0d | start no earlier than 2011-06-27 | H-A MECH TECH | 8h |  |
| 304 | 1.12.22.17 | lower and position septum platform |  | 1d? | 2011-08-02 | 2011-08-02 | 303 | 4d | 0d | start no earlier than 2011-06-28 | H-A MECH TECH | 8h |  |
| 305 | 1.12.22.18 | install catwalk on right access platform |  | 1d? | 2011-08-03 | 2011-08-03 | 304 | 4d | 0d |  | H-A MECH TECH | 8h |  |
| 306 | 1.12.22.19 | install upper platform stairs |  | 1d? | 2011-08-04 | 2011-08-04 | 305 | 4d | 0d |  | H-A MECH TECH | 8h |  |
| 308 | 1.12.22.20 | install target dewar and stand |  | 1d? | 2011-08-05 | 2011-08-05 | 306 | 4d | 0d | start no earlier than 2011-08-02 | H-A MECH TECH; TARGET GROUP TECH | 16h |  |
| 309 | 1.12.22.21 | connect dewar controls |  | 2d? | 2011-08-08 | 2011-08-09 | 308 | 4d | 0d |  | TARGET GROUP TECH | 16h |  |
| 310 | 1.12.22.22 | install dewar U tubes and return lines |  | 2d? | 2011-08-10 | 2011-08-11 | 309 | 4d | 0d |  | TARGET GROUP TECH | 16h |  |
| 311 | 1.12.22.23 | install beam lines |  | 1d? | 2011-08-12 | 2011-08-12 | 310 | 4d | 0d | start no earlier than 2011-08-12 | H-A MECH TECH | 8h | SOT |
| 312 | 1.12.22.24 | install Helium bags |  | 1d? | 2011-08-15 | 2011-08-15 | 311 | 4d | 0d | start no earlier than 2011-07-05 | H-A MECH TECH | 8h | SOT |
| 313 | 1.12.22.25 | install target vacuum pump power |  | 2d? | 2011-08-16 | 2011-08-17 | 312 | 4d | 0d |  | ELECTRICIAN (TECH) | 16h |  |
| 314 | 1.12.22.26 | install target vacuum pump plumbing |  | 4d? | 2011-08-18 | 2011-08-23 | 313 | 4d | 0d |  | TARGET GROUP TECH; H-A MECH TECH | 64h |  |
| 315 | 1.12.22.27 | install target vacuum system instr. and controls |  | 3d? | 2011-08-24 | 2011-08-26 | 314 | 4d | 3d |  | TARGET GROUP TECH | 24h | SOT |
| 316 | 1.12.22.28 | milestone for moving magnetto the Hall | milestone | 0d? | 2011-09-01 | 2011-09-01 | 315 | 1d | 0d | start no earlier than 2011-09-01 |  |  |  |

| ID | WBS | Task | Duration | Start | Finish | Predecessors | Total slack | Free slack | Constraint | Resources | Work | Text1 |
| --- | --- | --- | --- | --- | --- | --- | --- | --- | --- | --- | --- | --- |
| 317 | 1.12.23 | **re-assemble target assembly in Hall** | 10d? | 2011-09-01 | 2011-09-15 |  | 1d |  |  |  | 48h |  |
| 318 | 1.12.23.1 | move target parts to Hall | 1d? | 2011-09-01 | 2011-09-01 | 316 | 1d | 0d | start no earlier than 2011-09-01 |  |  |  |
| 319 | 1.12.23.2 | install chamber into rotating support ring | 1d? | 2011-09-02 | 2011-09-02 | 318 | 1d | 0d |  |  |  |  |
| 320 | 1.12.23.3 | install shield in chamber | 1d? | 2011-09-06 | 2011-09-06 | 319 | 1d | 0d | start no earlier than 2011-08-31 |  |  |  |
| 321 | 1.12.23.4 | install magnet into chamber | 1d? | 2011-09-07 | 2011-09-07 | 320 | 1d | 0d |  | TARGET GROUP TECH | 8h |  |
| 322 | 1.12.23.5 | align magnet in chamber (check as found) | 1d | 2011-09-08 | 2011-09-08 | 321 | 1d | 0d |  | MECH ALIGN TECH [200%] | 16h | SOT |
| 323 | 1.12.23.6 | install refrigerator | 1d? | 2011-09-09 | 2011-09-09 | 322 | 1d | 0d |  |  |  |  |
| 324 | 1.12.23.7 | install target and refrig. Inst, and controls | 2d? | 2011-09-12 | 2011-09-13 | 323 | 1d | 0d | start no earlier than 2011-09-12 | TARGET GROUP TECH | 16h | SOT |
| 325 | 1.12.23.8 | test magnet rotation system | 1d? | 2011-09-14 | 2011-09-14 | 324 | 1d | 0d |  | TARGET GROUP TECH | 8h | SOT |
| 326 | 1.12.23.9 | Ops software support | 1d? | 2011-09-15 | 2011-09-15 |  | 1d | 0d | start no earlier than 2011-09-15 |  |  |  |
| 327 | 1.12.23.10 | ops check motion mechanism | 1d? | 2011-09-15 | 2011-09-15 | 325, 326SS | 1d | 0d | start no earlier than 2011-09-15 |  |  |  |
| 329 | 1.12.24 | **install target assembly on pivot** | 46d? | 2011-09-16 | 2011-11-18 |  | 0d |  |  |  | 536h |  |
| 330 | 1.12.24.1 | install refrigerator pump on upper target balcony | 1d? | 2011-09-16 | 2011-09-16 | 327 | 1d | 0d | start no earlier than 2011-08-02 | TARGET GROUP TECH | 8h |  |
| 331 | 1.12.24.2 | roll septum/target platform into position | 1d? | 2011-09-19 | 2011-09-19 | 330 | 1d | 0d | start no earlier than 2011-06-27 | H-A MECH TECH | 8h |  |
| 332 | 1.12.24.3 | lower and position septum platform | 1d? | 2011-09-20 | 2011-09-20 | 331 | 1d | 0d | start no earlier than 2011-06-28 | H-A MECH TECH | 8h |  |
| 333 | 1.12.24.4 | align septum magnet | 2d | 2011-09-21 | 2011-09-22 | 332 | 1d | 0d | start no earlier than 2011-06-29 | MECH ALIGN TECH [200%] | 32h | SOT |
| 334 | 1.12.24.5 | align target chamber | 2d | 2011-09-23 | 2011-09-26 | 333 | 1d | 0d | start no earlier than 2011-06-30 | MECH ALIGN TECH [200%] | 32h | SOT |
| 335 | 1.12.24.6 | align magnet in chamber (check as found | 1d? | 2011-09-27 | 2011-09-27 | 334 | 1d | 0d |  | MECH ALIGN TECH [200%] | 16h | SOT |
| 336 | 1.12.24.7 | final alignment of Dump | 3d? | 2011-09-28 | 2011-09-30 | 335 | 1d | 0d |  | MECH ALIGN TECH [200%] | 48h |  |
| 337 | 1.12.24.8 | both spectrometers to 12.5 deg | 1d? | 2011-10-03 | 2011-10-03 | 336 | 33d | 0d | start no earlier than 2011-10-02 | H-A MECH TECH | 8h | SOT |
| 338 | 1.12.24.9 | install catwalk on right access platform | 1d? | 2011-10-03 | 2011-10-03 | 336 | 1d | 0d |  | H-A MECH TECH | 8h |  |
| 339 | 1.12.24.10 | survey both spectrometers | 1d? | 2011-10-04 | 2011-10-04 | 337 | 33d |  | start no earlier than 2011-10-02 | MECH ALIGN TECH [200%] | 16h | SOT |
| 340 | 1.12.24.11 | install upper platform stairs | 1d? | 2011-10-04 | 2011-10-04 | 338 | 1d | 0d | start no earlier than 2011-10-04 | H-A MECH TECH | 8h |  |
| 341 | 1.12.24.12 | install beam lines | 1d? | 2011-10-05 | 2011-10-05 | 340 | 1d | 0d | start no earlier than 2011-08-24 | H-A MECH TECH | 8h | SOT |
| 342 | 1.12.24.13 | align beam lines | 1d? | 2011-10-06 | 2011-10-06 | 341 | 1d | 0d |  | MECH ALIGN TECH [200%] | 16h | SOT |
| 343 | 1.12.24.14 | install Helium bags | 1d? | 2011-10-07 | 2011-10-07 | 342 | 1d | 0d | start no earlier than 2011-07-05 | H-A MECH TECH | 8h | SOT |
| 344 | 1.12.24.15 | install target vacuum pump power | 3d? | 2011-10-10 | 2011-10-12 | 343 | 1d | 0d |  | ELECTRICIAN (TECH) | 24h |  |
| 345 | 1.12.24.16 | install target vacuum pump plumbing | 2d? | 2011-10-13 | 2011-10-14 | 344 | 1d | 0d |  | TARGET GROUP TECH; H-A MECH TECH | 32h |  |
| 346 | 1.12.24.17 | install target vacuum system instr. and controls | 2d? | 2011-10-17 | 2011-10-18 | 345 | 1d | 0d |  | TARGET GROUP TECH | 16h | SOT |
| 347 | 1.12.24.18 | connect target vacuum system | 3d? | 2011-10-19 | 2011-10-21 | 346 | 1d | 0d | start no earlier than 2011-09-26 | TARGET GROUP TECH | 24h |  |
| 348 | 1.12.24.19 | leak check target vacuum system | 2d? | 2011-10-24 | 2011-10-25 | 347 | 1d | 0d | start no earlier than 2011-10-03 | TARGET GROUP TECH | 16h | SOT |
| 349 | 1.12.24.20 | install target chamber windows | 1d? | 2011-10-26 | 2011-10-26 | 348 | 1d | 0d | start no earlier than 2011-07-29 | H-A MECH TECH | 8h |  |
| 350 | 1.12.24.21 | pump down chamber | 2d? | 2011-10-27 | 2011-10-28 | 349 | 1d | 0d | start no earlier than 2011-08-02 | H-A MECH TECH | 16h | SOT |
| 351 | 1.12.24.22 | leak check chamber | 1d? | 2011-10-31 | 2011-10-31 | 350 | 1d | 0d | start no earlier than 2011-08-03 | H-A MECH TECH; TARGET GROUP TECH | 16h | SOT |
| 352 | 1.12.24.23 | insert target refrigerator | 3d? | 2011-11-01 | 2011-11-03 | 351 | 1d | 0d | start no earlier than 2011-08-04 | TARGET GROUP TECH | 24h |  |
| 353 | 1.12.24.24 | sting dewar to refrig and refrig to target | 1d? | 2011-11-04 | 2011-11-04 | 352 | 1d | 0d |  | TARGET GROUP TECH | 8h |  |
| 354 | 1.12.24.25 | pump and purge target cryo system | 2d? | 2011-11-07 | 2011-11-08 | 353 | 1d | 0d |  | TARGET GROUP TECH | 16h | SOT |
| 355 | 1.12.24.26 | fill dewar | 3d? | 2011-11-09 | 2011-11-11 | 354 | 1d | 0d |  | TARGET GROUP TECH | 24h | SOT |
| 356 | 1.12.24.27 | cool down target cryo system | 2d? | 2011-11-14 | 2011-11-15 | 355 | 1d |  | start no earlier than 2011-11-07 | TARGET GROUP TECH | 16h | SOT |
| 357 | 1.12.24.28 | test target refrigerator | 2d? | 2011-11-15 | 2011-11-16 | 355 | 2d |  | start no earlier than 2011-11-15 | TARGET GROUP TECH | 16h | SOT |
| 358 | 1.12.24.29 | ops check target system | 2d? | 2011-11-17 | 2011-11-18 | 356 | 0d |  | start no earlier than 2011-11-17 | TARGET GROUP TECH | 16h | SOT |
| 359 | 1.12.24.30 | software checkout and ops check | 5d | 2011-10-31 | 2011-11-04 | 346 | 10d |  | start no earlier than 2011-10-31 | OPS SOFTWARE | 40h |  |

| ID | WBS | Task | Type | Duration | Start | Finish | Predecessors | Total slack | Free slack | Constraint | Resources | Work | Text1 |
| --- | --- | --- | --- | --- | --- | --- | --- | --- | --- | --- | --- | --- | --- |
| 361 | 1.12.25 | **outages** |  | 11d? | 2011-05-20 | 2011-06-06 |  | 117d |  |  |  |  |  |
| 362 | 1.12.25.1 | May power outage Saterday |  | 2d? | 2011-05-20 | 2011-05-23 | 39 | 124d | 7d | start no earlier than 2011-05-20 |  |  |  |
| 363 | 1.12.25.2 | June power outage Saterday |  | 2d? | 2011-06-03 | 2011-06-06 | 362 | 117d | 116d | start no earlier than 2011-06-03 |  |  |  |
| 365 | 1.12.26 | **end stuff** |  | 14d? | 2011-10-31 | 2011-11-18 |  | 1d |  |  |  | 200h | XXXXXX |
| 366 | 1.12.26.1 | inspect beam dump as requested by RADCON |  | 1d? | 2011-10-31 | 2011-10-31 | 39 | 14d |  | start no earlier than 2011-10-31 | RADCON TECH | 8h |  |
| 367 | 1.12.26.2 | final removal |  | 10d? | 2011-10-31 | 2011-11-11 |  | 3d | 0d | start no earlier than 2011-10-31 | H-A MECH TECH | 80h | SOT |
| 368 | 1.12.26.3 | start power supplies |  | 2d? | 2011-11-07 | 2011-11-08 | 367SS | 5d | 1d | start no earlier than 2011-11-07 | H-A MECH TECH | 16h | SOT |
| 369 | 1.12.26.4 | cleanup |  | 10d? | 2011-10-31 | 2011-11-11 | 367SS | 3d | 1d | start no earlier than 2011-10-31 | H-A MECH TECH | 80h | SOT |
| 370 | 1.12.26.5 | hot check out checklist |  | 1d? | 2011-11-10 | 2011-11-10 | 368 | 4d | 2d | start no earlier than 2011-11-10 | H-A MECH TECH | 8h | SOT |
| 371 | 1.12.26.6 | restore beam |  | 1d? | 2011-11-15 | 2011-11-15 | 370, 369, 367 | 2d | 1d | start no earlier than 2011-11-15 |  |  | SOT |
| 372 | 1.12.26.7 | final checklist |  | 1d? | 2011-11-17 | 2011-11-17 | 371 | 1d | 0d | start no earlier than 2011-11-17 | H-A MECH TECH | 8h | SOT |
| 373 | 1.12.26.8 | run beam | milestone | 0d? | 2011-11-18 | 2011-11-18 | 372, 363 | 1d |  | start no earlier than 2011-11-18 |  |  | OPS |
| 375 | 1.12.27 | **stuff to do** |  | 32d? | 2011-05-16 | 2011-06-29 |  | 100d |  |  |  |  | XXXXXX |
| 376 | 1.12.27.1 | grease bogies |  | 2d? | 2011-06-27 | 2011-06-28 |  | 100d | 0d | start no earlier than 2011-06-27 |  |  | SOT |
| 377 | 1.12.27.2 | grease central bearing |  | 1d? | 2011-06-29 | 2011-06-29 | 376 | 100d |  |  |  |  | SOT |
| 378 | 1.12.27.3 | install water manifold on upper LCW |  | 1d? | 2011-05-16 | 2011-05-16 |  | 131d |  |  |  |  |  |
| 379 | 1.12.27.4 | install water manifold on PS balconies |  | 1d? | 2011-05-16 | 2011-05-16 |  | 131d |  |  |  |  |  |
| 380 | 1.12.27.5 | install new guards and heaters |  | 1d? | 2011-05-16 | 2011-05-16 |  | 131d |  |  |  |  |  |
| 381 | 1.12.27.6 | complete BB rigid water lines |  | 1d? | 2011-05-16 | 2011-05-16 |  | 131d |  |  |  |  |  |
| 382 | 1.12.27.7 | calibrate LL meters |  | 1d? | 2011-05-16 | 2011-05-16 |  | 131d |  |  |  |  |  |
| 383 | 1.12.27.8 | warm up Q-1 magnets |  | 1d? | 2011-05-16 | 2011-05-16 |  | 131d |  |  |  |  | SOT |
| 384 | 1.12.27.9 | de-sting Q-1 magnets |  | 1d? | 2011-05-16 | 2011-05-16 |  | 131d |  |  |  |  |  |
| 385 | 1.12.27.10 | rework leads on left Q1 |  | 1d? | 2011-05-16 | 2011-05-16 |  | 131d |  |  |  |  |  |
| 386 | 1.12.27.11 | clean out cable trays |  | 1d? | 2011-05-16 | 2011-05-16 |  | 131d |  |  |  |  | SOT |
| 387 | 1.12.27.12 | install manual flow meters on Q2/Q3 |  | 1d? | 2011-05-16 | 2011-05-16 |  | 131d |  |  |  |  | SOT |
| 388 | 1.12.27.13 | grease shield house doors |  | 1d? | 2011-05-16 | 2011-05-16 |  | 131d |  |  |  |  |  |
| 389 | 1.12.27.14 | re-insulate warm return lines |  | 1d? | 2011-05-16 | 2011-05-16 |  | 131d |  |  |  |  |  |
| 390 | 1.12.27.15 | repair leaks in exit beam pipe |  | 1d? | 2011-05-16 | 2011-05-16 |  | 131d |  |  |  |  |  |
| 391 | 1.12.27.16 | install DP gauges on LCW system |  | 1d? | 2011-05-16 | 2011-05-16 |  | 131d |  |  |  |  |  |
| 392 | 1.12.27.17 | install DP gauge on BB water system |  | 1d? | 2011-05-16 | 2011-05-16 |  | 131d |  |  |  |  |  |
| 393 | 1.12.27.18 | new lead guards on Q2/Q3 |  | 1d? | 2011-05-16 | 2011-05-16 |  | 131d |  |  |  |  | SOT |
| 394 | 1.12.27.19 | new lead guards on Dipoles |  | 1d? | 2011-05-16 | 2011-05-16 |  | 131d |  |  |  |  | SOT |
| 395 | 1.12.27.20 | new lead guards on Q1s |  | 1d? | 2011-05-16 | 2011-05-16 |  | 131d |  |  |  |  | SOT |
| 396 | 1.12.27.21 | Lt Q1 power supply maintenance |  | 1d? | 2011-05-16 | 2011-05-16 |  | 131d |  |  |  |  |  |
| 397 | 1.12.27.22 | Lt Q2 power supply maintenance |  | 1d? | 2011-05-16 | 2011-05-16 |  | 131d |  |  |  |  |  |
| 398 | 1.12.27.23 | Lt Dipole power supply maintenance |  | 1d? | 2011-05-16 | 2011-05-16 |  | 131d |  |  |  |  |  |
| 399 | 1.12.27.24 | Rt Q1 power supply maintenance |  | 1d? | 2011-05-16 | 2011-05-16 |  | 131d |  |  |  |  |  |
| 400 | 1.12.27.25 | Rt Q2 power supply maintenance |  | 1d? | 2011-05-16 | 2011-05-16 |  | 131d |  |  |  |  |  |
| 401 | 1.12.27.26 | Rt Dipole power supply maintenance |  | 1d? | 2011-05-16 | 2011-05-16 |  | 131d |  |  |  |  |  |
| 402 | 1.12.27.27 | Rt Q3 power supply maintenance |  | 1d? | 2011-05-16 | 2011-05-16 |  | 131d |  |  |  |  |  |
| 403 | 1.12.27.28 | repair right transfer line |  | 1d? | 2011-05-16 | 2011-05-16 |  | 131d |  |  |  |  |  |
| 404 | 1.12.27.29 | replace left Q2 016 weka valve |  | 1d? | 2011-05-16 | 2011-05-16 |  | 131d |  |  |  |  |  |
| 405 | 1.12.27.30 | remove maintenance jacks from both spectrometers |  | 1d? | 2011-05-16 | 2011-05-16 |  | 131d |  |  |  |  |  |
| 406 | 1.12.27.31 | finish vacuum line extension on Rt Q3 |  | 1d? | 2011-05-16 | 2011-05-16 |  | 131d |  |  |  |  |  |
| 407 | 1.12.27.32 | visual inspection of exit BP diffuser |  | 1d? | 2011-05-16 | 2011-05-16 |  | 131d |  |  |  |  |  |
| 408 | 1.12.27.33 | Upgrade/ reinforce BB support arm and extensions |  | 1d? | 2011-05-16 | 2011-05-16 |  | 131d |  |  |  |  |  |
| 409 | 1.12.27.34 | Rework PHPK cryo cans for pivot distribution |  | 1d? | 2011-05-16 | 2011-05-16 |  | 131d |  |  |  |  |  |
| 410 | 1.12.27.35 | modify and install stairs |  | 1d? | 2011-05-16 | 2011-05-16 |  | 131d |  |  |  |  |  |
| 411 | 1.12.27.36 | install local valve controler to exit beam pipe valve |  | 1d? | 2011-05-16 | 2011-05-16 |  | 131d |  |  |  |  |  |
