# SBS Installation

Schedule from MS Project, 2020-09-21 to 2021-10-01, status date 2021-06-23, A marks actual dates.
JLAB

## Calendars

- Standard: Mon-Fri 08:00-12:00, 13:00-17:00; Sat-Sun off. Exceptions (off unless hours are given): 2020-11-26 to 2020-11-27 (Thanksgiving Holiday), 2020-12-23 to 2021-01-04 (Holiday Shutdown), 2021-01-18 (MLK Day), 2021-05-31 (Memorial Day), 2021-07-05 (July 4th).

## Schedule

| ID | WBS | Task | Type | Duration | Start | Finish | Predecessors | Complete | Remaining | Total slack | Free slack | Constraint |
| --- | --- | --- | --- | --- | --- | --- | --- | --- | --- | --- | --- | --- |
| 1 | 1 | **SBS Installation Schedule** |  | 256d? | 2020-09-21 A | 2021-10-01 |  | 21% | 203.06d? | 0d |  |  |
| 2 | 1.1 | **Milestones** |  | 254d | 2020-09-21 A | 2021-09-30 |  |  | 254d | 2d |  |  |
| 3 | 1.1.1 | Post Beam Checklist - Installation Begins | milestone | 0d | 2020-09-21 A | 2020-09-21 A |  | 100% |  |  |  |  |
| 4 | 1.1.2 | Turn Off LCW Supply to Hall (need to be coordinated with other halls) | milestone | 0d | 2020-09-21 A | 2020-09-21 A |  | 100% |  |  |  | start no earlier than 2020-09-21 |
| 5 | 1.1.3 | Turn Main LCW System Back On (coordinate with C. Jones) | milestone | 0d | 2020-10-02 A | 2020-10-02 A |  | 100% |  |  |  | start no earlier than 2020-10-02 |
| 6 | 1.1.4 | LCW Upgrade Complete | milestone | 0d | 2020-10-23 | 2020-10-23 |  |  |  | 232d |  | start no earlier than 2020-10-23 |
| 7 | 1.1.5 | PREX/CREX Removal Complete - Power Upgrade Work Can Begin (inside the Hall) | milestone | 0d | 2020-11-23 A | 2020-11-23 A |  | 100% |  |  |  | start no earlier than 2020-11-23 |
| 8 | 1.1.6 | RHRS Decommissioning Complete - Replacement of Main AHU Begins | milestone | 0d | 2021-02-16 | 2021-02-16 |  |  |  | 162d |  | start no earlier than 2021-02-16 |
| 9 | 1.1.7 | Prepare Initial Set of Equipment Racks for Transporting to Hall (not involved in testing) | milestone | 0d | 2021-03-12 | 2021-03-12 |  |  |  | 144d |  | start no earlier than 2021-03-12 |
| 10 | 1.1.8 | Begin Connecting Electronics in Upstream Bunker (Collaboration) | milestone | 0d | 2021-04-09 | 2021-04-09 |  |  |  | 124d |  | start no earlier than 2021-04-09 |
| 11 | 1.1.9 | Remaining Big Bite Equipment Ready to Transport to Hall | milestone | 0d | 2021-05-25 | 2021-05-25 |  |  |  | 92d |  | start no earlier than 2021-05-25 |
| 12 | 1.1.10 | Begin Cool Down of LHRS | milestone | 0d | 2021-06-01 | 2021-06-01 |  |  |  | 88d |  | start no earlier than 2021-06-01 |
| 13 | 1.1.11 | Remaining SBS Equipment Ready to Transport to Hall | milestone | 0d | 2021-06-04 | 2021-06-04 |  |  |  | 85d |  | start no earlier than 2021-06-04 |
| 14 | 1.1.12 | Connect Electronics in Big Bite Equipment Racks (Collaboration) | milestone | 0d | 2021-06-21 | 2021-06-21 |  |  |  | 74d |  | start no earlier than 2021-06-21 |
| 15 | 1.1.13 | Begin Connecting HCAL Electronics - Detector End (collaboration) | milestone | 0d | 2021-08-13 | 2021-08-13 |  |  |  | 36d |  | start no earlier than 2021-08-13 |
| 16 | 1.1.14 | Begin Connecting GeN-RP Electronic - Detector End | milestone | 0d | 2021-08-13 | 2021-08-13 |  |  |  | 36d |  | start no earlier than 2021-08-13 |
| 17 | 1.1.15 | Complete Pre-Beam Checklist - Installation Complete | milestone | 0d | 2021-09-30 | 2021-09-30 |  |  |  | 2d |  | start no earlier than 2021-09-30 |
| 18 | 1.2 | **Preliminaries** |  | 19d | 2020-09-21 A | 2020-10-15 A |  | 100% |  |  |  |  |
| 19 | 1.2.1 | Post Beam Checklist - Installation Begins | milestone | 0d | 2020-09-21 A | 2020-09-21 A |  | 100% |  |  |  |  |
| 20 | 1.2.2 | RADCON Survey / Hold Around Pivot |  | 19d | 2020-09-21 A | 2020-10-15 A |  | 100% |  |  |  |  |
| 21 | 1.3 | **FML Work List (maintained by FML)** |  | 117d | 2020-09-21 | 2021-03-18 |  |  |  | 139d |  |  |
| 22 | 1.3.1 | LCW Pressure Sensor |  | 5d | 2020-10-02 | 2020-10-08 | 41 |  |  | 140d | 0d |  |
| 23 | 1.3.2 | Various Water Leak Repairs |  | 40d | 2020-10-09 | 2020-12-07 | 22 |  |  | 140d | 0d |  |
| 24 | 1.3.3 | Hall A 2MVA Power Upgrade |  | 20d | 2020-12-08 | 2021-01-15 | 94, 23 |  |  | 140d | 0d |  |
| 25 | 1.3.4 | Electrical Retrofits Due to Detector Rotation |  | 9d | 2021-01-19 | 2021-01-29 | 24 |  |  | 140d | 0d |  |
| 26 | 1.3.5 | Relocate ODH Monitor / Alarm System |  | 9d | 2021-02-01 | 2021-02-11 | 25 |  |  | 140d | 0d |  |
| 27 | 1.3.6 | HVAC Retrofits Due to Detector Rotation |  | 10d | 2021-02-12 | 2021-02-25 | 26 |  |  | 140d | 1d |  |
| 28 | 1.3.7 | Hall A HVAC Replacement |  | 14d | 2021-03-01 | 2021-03-18 | 27, 126 |  |  | 139d |  |  |
| 29 | 1.3.8 | LCW Heat Exchanger [scheduling postponed] |  | 4d | 2020-09-21 | 2020-09-24 |  |  |  | 252d |  |  |
| 30 | 1.3.9 | Lighting Replacement [scheduling postponed] |  | 4d | 2020-09-21 | 2020-09-24 |  |  |  | 252d |  |  |
| 31 | 1.3.10 | Replace Obsolete XL100 Honeywell Controller [scheduling postponed] |  | 4d | 2020-09-21 | 2020-09-24 |  |  |  | 252d |  |  |
| 32 | 1.3.11 | Fire Safety System: Smoke Removal Fans Replacement [scheduling postponed] |  | 4d | 2020-09-21 | 2020-09-24 |  |  |  | 252d |  |  |
| 33 | 1.3.12 | Beam Dump Cooling Study [scheduling postponed] |  | 4d | 2020-09-21 | 2020-09-24 |  |  |  | 252d |  |  |
| 34 | 1.3.13 | Beam Dump Cooling Capacity Increase [scheduling postponed] |  | 4d | 2020-09-21 | 2020-09-24 |  |  |  | 252d |  |  |
| 35 | 1.3.14 | Nitrogen Vaporizer for Dehumidification System [scheduling postponed] |  | 4d | 2020-09-21 | 2020-09-24 |  |  |  | 252d |  |  |
| 36 | 1.3.15 | Fire Safety System: End Station Fire Detection and Suppression [scheduling postponed] |  | 4d | 2020-09-21 | 2020-09-24 |  |  |  | 252d |  |  |
| 37 | 1.3.16 | LCW Pressure Regulation (Hall B) [scheduling postponed] |  | 4d | 2020-09-21 | 2020-09-24 |  |  |  | 252d |  |  |

| ID | WBS | Task | Type | Duration | Start | Finish | Predecessors | Complete | Remaining | Total slack | Free slack | Constraint |
| --- | --- | --- | --- | --- | --- | --- | --- | --- | --- | --- | --- | --- |
| 38 | 1.4 | **LCW Upgrade (has separate detailed drawings & procedure)** |  | 34d | 2020-09-21 A | 2020-11-05 |  | 82% | 6d | 222d |  |  |
| 39 | 1.4.1 | Shut Off LCW Entering the Hall and Drain System |  | 4d | 2020-09-21 A | 2020-09-24 A |  | 100% |  |  |  |  |
| 40 | 1.4.2 | Remove downstream (4") section of pipe that connects to arms |  | 5d | 2020-09-25 A | 2020-10-01 A | 39 | 100% |  |  |  |  |
| 41 | 1.4.3 | Turn Off LCW Supply to Hall (need to be coordinated with other halls) | milestone | 0d | 2020-10-01 A | 2020-10-01 A | 40 | 100% |  |  |  | start no earlier than 2020-09-21 |
| 42 | 1.4.4 | Drain System and relieve pressure Upstream of Main (8") Valves |  | 1d | 2020-10-02 A | 2020-10-02 A | 40 | 100% |  |  |  |  |
| 43 | 1.4.5 | Contact FML To Remove Pressure/Flow Sensors |  | 1d | 2020-10-05 A | 2020-10-05 A | 40, 42 | 100% |  |  |  |  |
| 44 | 1.4.6 | Remove 8" Valves |  | 1d | 2020-10-06 A | 2020-10-06 A | 43 | 100% |  |  |  |  |
| 45 | 1.4.7 | Cut Off 90 Degree Elbows on 8" Lines |  | 2d | 2020-10-07 A | 2020-10-08 A | 44 | 100% |  |  |  |  |
| 46 | 1.4.8 | Install New Flanges on 8" Pipes |  | 2d | 2020-10-09 A | 2020-10-12 A | 45 | 100% |  |  |  |  |
| 47 | 1.4.9 | Install New 8" Valves |  | 1d | 2020-10-13 A | 2020-10-13 A | 46 | 100% |  |  |  |  |
| 48 | 1.4.10 | Install 8" to 4" Manifolds |  | 2d | 2020-10-14 A | 2020-10-15 A | 47 | 100% |  |  |  |  |
| 49 | 1.4.11 | Turn Main LCW System Back On (coordinate with C. Jones) | milestone | 0d | 2020-10-15 A | 2020-10-15 A | 48 | 100% |  |  |  |  |
| 50 | 1.4.12 | Reconnect 4" LCW Lines Going to Pivot |  | 2d | 2020-10-16 A | 2020-10-19 A | 48 | 100% |  |  |  |  |
| 51 | 1.4.13 | Position New LCW Structure and Manifold |  | 1d | 2020-10-20 A | 2020-10-20 A | 50 | 100% |  |  |  |  |
| 52 | 1.4.14 | Weld in 4" Line Going Down to New Manifold |  | 2d | 2020-10-21 A | 2020-10-22 A | 51 | 100% |  |  |  |  |
| 53 | 1.4.15 | Connect New Manifold to LCW System |  | 1d | 2020-10-23 A | 2020-10-23 A | 52 | 100% |  |  |  |  |
| 54 | 1.4.16 | Disconnect & Cap Water Lines Over the Pivot Going to RHRS |  | 3d | 2020-10-26 A | 2020-10-28 A | 53 | 100% |  |  |  |  |
| 55 | 1.4.17 | Pressurize LCW System and Check For Leaks |  | 1d | 2020-10-29 | 2020-10-29 | 54 |  |  | 222d | 0d |  |
| 56 | 1.4.18 | Complete Pressure Test of New Section of LCW for Engineering Checkout |  | 3d | 2020-10-30 | 2020-11-03 | 55 |  |  | 222d | 0d |  |
| 57 | 1.4.19 | Document and Signoff on In-Service LCW System. |  | 2d | 2020-11-04 | 2020-11-05 | 56 |  |  | 222d | 0d |  |
| 58 | 1.4.20 | LCW Upgrade Complete | milestone | 0d | 2020-11-05 | 2020-11-05 | 57 |  |  | 222d |  |  |
| 59 | 1.5 | **Target Group Work (Target Group has details)** |  | 29d | 2020-09-21 A | 2020-10-29 |  | 75% | 7.25d | 227d |  |  |
| 60 | 1.5.1 | Warm Up Target (PREX/CREX) [anticipated] |  | 2d | 2020-09-21 A | 2020-09-22 A |  | 100% |  |  |  |  |
| 61 | 1.5.2 | Bleed Up and Open Target Chamber (PREX/CREX) [anticipated] |  | 2d | 2020-10-16 A | 2020-10-19 A | 20, 60 | 100% |  |  |  |  |
| 62 | 1.5.3 | Complete as Found Surveys on Target and HRS (PREX/CREX) [anticipated] |  | 3d | 2020-10-20 A | 2020-10-22 A | 61 | 100% |  |  |  |  |
| 63 | 1.5.4 | Remove Target (PREX/CREX) [anticipated] |  | 5d | 2020-10-23 A | 2020-10-29 A | 62 | 100% |  |  |  |  |
| 64 | 1.5.5 | Install Target (SBS) [scheduling postponed] |  | 1d | 2020-09-21 | 2020-09-21 |  |  |  | 255d |  |  |
| 65 | 1.5.6 | Complete Startup Surveys [scheduling postponed] |  | 1d | 2020-09-21 | 2020-09-21 |  |  |  | 255d |  |  |
| 66 | 1.5.7 | Close and Pump Down Chamber (SBS) [scheduling postponed] |  | 1d | 2020-09-21 | 2020-09-21 |  |  |  | 255d |  |  |
| 67 | 1.5.8 | Cool Down Target (SBS) [scheduling postponed] |  | 1d | 2020-09-21 | 2020-09-21 |  |  |  | 255d |  |  |

| ID | WBS | Task | Type | Duration | Start | Finish | Predecessors | Complete | Remaining | Total slack | Constraint |
| --- | --- | --- | --- | --- | --- | --- | --- | --- | --- | --- | --- |
| 68 | 1.6 | **Decommission RHRS & Positioning LHRS** |  | 196d | 2020-09-21 A | 2021-07-12 |  | 50% | 97.56d | 60d |  |
| 69 | 1.6.1 | **Bleed Up Vacuum Systems** |  | 1d | 2020-09-21 A | 2020-09-21 A |  | 100% |  |  |  |
| 70 | 1.6.1.1 | Bleed Up Entrance Beam Line (downstream of raster) |  | 1d | 2020-09-21 A | 2020-09-21 A |  | 100% |  |  |  |
| 71 | 1.6.1.2 | Bleed Up Exit Beam Line |  | 1d | 2020-09-21 A | 2020-09-21 A |  | 100% |  |  |  |
| 72 | 1.6.1.3 | Bleed Up Both Spectrometers |  | 1d | 2020-09-21 A | 2020-09-21 A |  | 100% |  |  |  |
| 73 | 1.6.2 | **Remove PREX/CREX Equipment** |  | 35d | 2020-10-16 A | 2020-12-07 A |  | 100% |  |  |  |
| 74 | 1.6.2.1 | Remove Pivot Fence |  | 1d | 2020-10-16 A | 2020-10-16 A | 20, 48 | 100% |  |  |  |
| 75 | 1.6.2.2 | Remove Ion Chamber Near Pivot (request through SSG) |  | 1d | 2020-10-19 A | 2020-10-19 A | 74 | 100% |  |  |  |
| 76 | 1.6.2.3 | Disconnect Chamber From Entrance Beam Line |  | 1d | 2020-10-20 A | 2020-10-20 A | 75 | 100% |  |  |  |
| 77 | 1.6.2.4 | Remove Turbo Pump and Valve From Chamber |  | 2d | 2020-10-21 A | 2020-10-22 A | 76 | 100% |  |  |  |
| 78 | 1.6.2.5 | Remove Poly-Blocks Between Chamber and Collimator |  | 2d | 2020-10-23 A | 2020-10-26 A | 77 | 100% |  |  |  |
| 79 | 1.6.2.6 | Remove Bellows and Valve Between Collimator and Chamber |  | 2d | 2020-10-27 A | 2020-10-28 A | 78 | 100% |  |  |  |
| 80 | 1.6.2.7 | Disconnect Exit Beam Line and Spectrometers' Feed-Thrus |  | 1d | 2020-10-29 A | 2020-10-29 A | 79 | 100% |  |  |  |
| 81 | 1.6.2.8 | Disconnect Septum Wiring |  | 3d | 2020-11-06 A | 2020-11-10 A | 80, 57 | 100% |  |  |  |
| 82 | 1.6.2.9 | Move Septum Magnet Upstream to Clear Spectrometer Nose (~4"-6") |  | 2d | 2020-11-11 A | 2020-11-12 A | 81 | 100% |  |  |  |
| 83 | 1.6.2.10 | Remove Left and Ride Side Work Platforms |  | 1d | 2020-11-13 A | 2020-11-13 A | 82 | 100% |  |  |  |
| 84 | 1.6.2.11 | Roll PREX/CREX Equipment Out to Beam Left |  | 1d | 2020-11-16 A | 2020-11-16 A | 83 | 100% |  |  |  |
| 85 | 1.6.2.12 | Remove Sky Shine Shielding and Support Structure |  | 2d | 2020-11-17 A | 2020-11-18 A | 84 | 100% |  |  |  |
| 86 | 1.6.2.13 | Remove Target Chamber and Base Plate |  | 1d | 2020-11-19 A | 2020-11-19 A | 85 | 100% |  |  |  |
| 87 | 1.6.2.14 | Remove Top Half of Septum Magnet |  | 2d | 2020-11-20 A | 2020-11-23 A | 86 | 100% |  |  |  |
| 88 | 1.6.2.15 | Remove Collimator, Concrete Shielding, and Vacuum Feed-Thrus From Bore of Septum |  | 1d | 2020-11-24 A | 2020-11-24 A | 87 | 100% |  |  |  |
| 89 | 1.6.2.16 | Reinstall Top Half of Septum Magnet |  | 2d | 2020-11-25 A | 2020-11-30 A | 88 | 100% |  |  |  |
| 90 | 1.6.2.17 | Remove Septum Magnet From Pivot |  | 1d | 2020-12-01 A | 2020-12-01 A | 89 | 100% |  |  |  |
| 91 | 1.6.2.18 | Remove Septum Magnet Base Plate |  | 1d | 2020-12-02 A | 2020-12-02 A | 90 | 100% |  |  |  |
| 92 | 1.6.2.19 | Remove Septum Magnet Carriage |  | 1d | 2020-12-03 A | 2020-12-03 A | 91 | 100% |  |  |  |
| 93 | 1.6.2.20 | Remove Bridge From Pivot |  | 2d | 2020-12-04 A | 2020-12-07 A | 92 | 100% |  |  |  |
| 94 | 1.6.2.21 | PREX/CREX Removal Complete - Power Upgrade Work Can Begin (inside the Hall) | milestone | 0d | 2020-12-07 A | 2020-12-07 A | 57, 93 | 100% |  |  | start no earlier than 2020-11-23 |
| 95 | 1.6.3 | Install Work Platform Around Distribution Can (removed from schedule) |  | 8d | 2020-12-08 A | 2020-12-17 A | 93 | 100% |  |  |  |
| 96 | 1.6.4 | Remove Right Q1 Magnet |  | 5d | 2020-12-18 A | 2021-01-06 A | 95 | 100% |  |  |  |

| ID | WBS | Task | Type | Duration | Start | Finish | Predecessors | Complete | Remaining | Total slack | Free slack | Constraint |
| --- | --- | --- | --- | --- | --- | --- | --- | --- | --- | --- | --- | --- |
| 97 | 1.6.5 | **Cryogenic Work (has a separate detailed procedure)** |  | 196d | 2020-09-21 A | 2021-07-12 |  | 63% | 72.59d | 43d |  |  |
| 98 | 1.6.5.1 | Power Supply Testing and Prep Work |  | 9d | 2020-09-21 A | 2020-10-01 A |  | 100% |  |  |  |  |
| 99 | 1.6.5.2 | Warm Up Cryogenic System |  | 15d | 2020-10-02 A | 2020-10-22 A | 98 | 100% |  |  |  |  |
| 100 | 1.6.5.3 | Disconnect RHRS From Cryogenic System |  | 20d | 2020-10-23 A | 2020-11-19 | 99 | 50% | 10d | 185d | 0d |  |
| 101 | 1.6.5.4 | Clean Up Cryogenic System |  | 10d | 2020-11-20 | 2020-12-07 | 100 |  |  | 185d | 0d |  |
| 102 | 1.6.5.5 | Begin Cool Down of LHRS | milestone | 0d | 2021-07-12 | 2021-07-12 |  |  |  | 24d | 0d | start no earlier than 2021-07-12 |
| 103 | 1.6.6 | Disconnect and Label Lines Going to RHRS (above pivot) |  | 10d | 2020-12-08 | 2020-12-21 | 93, 101 |  |  | 185d | 0d |  |
| 104 | 1.6.7 | Remove Detectors From RHRS |  | 6d | 2020-12-22 | 2021-01-11 | 103 |  |  | 5d | 0d |  |
| 105 | 1.6.8 | Remove SAMs (LUMIs) From Exit Beam Line and Cap Opening |  | 1d | 2021-01-12 | 2021-01-12 | 104 |  |  | 184d | 0d |  |
| 106 | 1.6.9 | Remove Bridge That Connects the Two Spectrometers |  | 1d | 2021-01-13 A | 2021-01-13 A | 105 | 100% |  |  |  |  |
| 107 | 1.6.10 | Clear Floor Space and Move RHRS to ~45 Degrees |  | 20d | 2020-12-08 A | 2021-01-15 A | 93, 101 | 100% |  |  |  |  |
| 108 | 1.6.11 | **Remove Big Box Power Supply From RHRS** |  | 13d | 2021-01-12 A | 2021-01-29 |  | 77% | 3d | 5d |  |  |
| 109 | 1.6.11.1 | Request Electrician to Disconnect Main Power to Big Box PS |  | 4d | 2021-01-12 A | 2021-01-15 A | 104 | 100% |  |  |  |  |
| 110 | 1.6.11.2 | Disconnect Water and Magnet's Leads |  | 2d | 2021-01-19 A | 2021-01-20 A | 107, 109 | 100% |  |  |  |  |
| 111 | 1.6.11.3 | Move (Walter's) Platform Table into Position on Inside of RHRS |  | 0.5d | 2021-01-21 A | 2021-01-21 A | 110 | 100% |  |  |  |  |
| 112 | 1.6.11.4 | Remove Shielding and Handrails From RHRS Platform |  | 0.5d | 2021-01-21 A | 2021-01-21 A | 111 | 100% |  |  |  |  |
| 113 | 1.6.11.5 | Remove Big Box Power Supply From RHRS Platform |  | 1d | 2021-01-22 A | 2021-01-22 A | 112 | 100% |  |  |  |  |
| 114 | 1.6.11.6 | Reinstall RHRS Platform Handrails |  | 0.5d | 2021-01-25 A | 2021-01-25 A | 113 | 100% |  |  |  |  |
| 115 | 1.6.11.7 | Place Big Box PS into its Original Position (behind green wall) |  | 0.5d | 2021-01-25 A | 2021-01-25 A | 114 | 100% |  |  |  |  |
| 116 | 1.6.11.8 | Remove Platform Table From the Hall (ask Walter where to put) |  | 1d | 2021-01-26 A | 2021-01-26 A | 115 | 100% |  |  |  |  |
| 117 | 1.6.11.9 | Request Electrician to reconnect Main Power to Big Box PS |  | 1d | 2021-01-27 | 2021-01-27 | 116 |  |  | 5d | 0d |  |
| 118 | 1.6.11.10 | Connect Magnet Leads (Big Bite) and Water to Big Box PS |  | 2d | 2021-01-28 | 2021-01-29 | 117 |  |  | 5d | 0d |  |
| 119 | 1.6.12 | **Move RHRS Pass Roll Up Door** |  | 43d | 2021-01-19 | 2021-03-18 |  |  |  | 0d |  |  |
| 120 | 1.6.12.1 | Continue Clearing Floor Space Behind Green Wall Area |  | 13d | 2021-01-19 | 2021-02-04 | 107 |  |  | 169d |  |  |
| 121 | 1.6.12.2 | Electrical Retrofits Due to Detector Rotation |  | 9d | 2021-01-19 | 2021-01-29 | 107 |  |  | 0d |  |  |
| 122 | 1.6.12.3 | Relocate ODH Monitor / Alarm System |  | 9d | 2021-02-01 | 2021-02-11 | 121 |  |  | 0d |  |  |
| 123 | 1.6.12.4 | Move Small AHU (see FML work list) |  | 10d | 2021-02-12 | 2021-02-25 | 122 |  |  | 0d |  |  |
| 124 | 1.6.12.5 | Remove Interfering Electronic Equipment Racks Behind Green Wall |  | 4d | 2021-02-01 | 2021-02-04 | 118 |  |  | 5d | 0d |  |
| 125 | 1.6.12.6 | Remove Post Underneath Pivot That Interferes With RHRS Movement |  | 10d | 2021-02-05 | 2021-02-18 | 124 |  |  | 5d |  |  |
| 126 | 1.6.12.7 | Move and Park RHRS Pass Roll Up Door |  | 1d | 2021-02-26 | 2021-02-26 | 125, 123 |  |  | 0d |  |  |
| 127 | 1.6.12.8 | RHRS Decommissioning Complete - Replacement of Main AHU Begins | milestone | 0d | 2021-02-26 | 2021-02-26 | 126 |  |  | 0d |  |  |
| 128 | 1.6.12.9 | Replace Main HVAC Unit |  | 14d | 2021-03-01 | 2021-03-18 | 126, 127 |  |  | 0d |  |  |

| ID | WBS | Task | Type | Duration | Start | Finish | Predecessors | Total slack | Free slack |
| --- | --- | --- | --- | --- | --- | --- | --- | --- | --- |
| 129 | 1.7 | **L-HRS & Exit Beamline Work** |  | 50d | 2021-03-19 | 2021-05-27 |  | 0d |  |
| 130 | 1.7.1 | **Prep / LHRS Work** |  | 25d | 2021-03-19 | 2021-04-22 |  | 0d |  |
| 131 | 1.7.1.1 | Clear Floor Space Needed to Move LHRS |  | 5d | 2021-03-19 | 2021-03-25 | 128 | 0d |  |
| 132 | 1.7.1.2 | Prepare Initial Set of Equipment Racks for Transporting to Hall (not involved in testing) | milestone | 0d | 2021-03-25 | 2021-03-25 | 131 | 134d |  |
| 133 | 1.7.1.3 | Rotate L-HRS Out to ~105 for Removing Exit Beamline |  | 1d | 2021-03-26 | 2021-03-26 | 131 | 0d |  |
| 134 | 1.7.1.4 | Install Upstream Electronics Bunker and Racks |  | 9d | 2021-03-29 | 2021-04-08 | 133 | 114d | 0d |
| 135 | 1.7.1.5 | Install SBS Power Supply in Upstream Bunker |  | 5d | 2021-04-09 | 2021-04-15 | 134 | 119d |  |
| 136 | 1.7.1.6 | Install Power Outlets in Upstream Bunker |  | 10d | 2021-04-09 | 2021-04-22 | 134 | 114d | 0d |
| 137 | 1.7.1.7 | Begin Connecting Electronics in Upstream Bunker (Collaboration) | milestone | 0d | 2021-04-22 | 2021-04-22 | 136 | 114d |  |
| 138 | 1.7.1.8 | Remove Shielding Blocks Underneath Exit Beamline |  | 2d | 2021-03-29 | 2021-03-30 | 133 | 0d |  |
| 139 | 1.7.2 | **Exit Beamline Work** |  | 50d | 2021-03-19 | 2021-05-27 |  | 5d |  |
| 140 | 1.7.2.1 | Disconnect Turbo And Instrumentation For Exit Beamline |  | 1d | 2021-03-19 | 2021-03-19 | 128 | 5d | 0d |
| 141 | 1.7.2.2 | Remove Beamline Between Chamber and Corragated (see drawings) |  | 2d | 2021-03-22 | 2021-03-23 | 140 | 5d |  |
| 142 | 1.7.2.3 | Layout Mounting Holes for Exit Beamline Tower (S&A) |  | 2d | 2021-03-31 | 2021-04-01 | 138, 141 | 0d |  |
| 143 | 1.7.2.4 | Install Exit Beamline Tower (see procedure for alignment requirements) |  | 10d | 2021-04-02 | 2021-04-15 | 142 | 0d |  |
| 144 | 1.7.2.5 | Remove Old Support Infrastructure for Exit Beamline |  | 10d | 2021-04-02 | 2021-04-15 | 142 | 0d |  |
| 145 | 1.7.2.6 | Install New flange for Connecting Shielded Beamline (see drawings) |  | 2d | 2021-04-16 | 2021-04-19 | 143, 144 | 117d |  |
| 146 | 1.7.2.7 | Install Turbo in New Position Along Exit Beamline (see drawings) |  | 5d | 2021-04-16 | 2021-04-22 | 143, 144 | 0d |  |
| 147 | 1.7.2.8 | Install Lower Section of Target Chamber |  | 1d | 2021-04-23 | 2021-04-23 | 146 | 0d |  |
| 148 | 1.7.2.9 | Install Isolation Valve Between Chamber and Exit Beamline |  | 1d | 2021-04-26 | 2021-04-26 | 147 | 0d |  |
| 149 | 1.7.2.10 | Assemble Correctors and Shielded Beamline Subassembly |  | 3d | 2021-04-27 | 2021-04-29 | 148 | 0d |  |
| 150 | 1.7.2.11 | Install Correctors and Shielded Beamline Subassembly on Tower |  | 1d | 2021-04-30 | 2021-04-30 | 149 | 0d |  |
| 151 | 1.7.2.12 | Check Alignment of Correctors and Shielded Beamline |  | 3d | 2021-05-03 | 2021-05-05 | 150 | 0d |  |
| 152 | 1.7.2.13 | Make Final Connections of Shielded Beamline: Chamber and Exit . |  | 1d | 2021-05-06 | 2021-05-06 | 151 | 0d |  |
| 153 | 1.7.2.14 | Install Temp Sensors on Correctors |  | 4d | 2021-05-07 | 2021-05-12 | 152 | 0d |  |
| 154 | 1.7.2.15 | Install Upper Section of Target Chamber |  | 1d | 2021-05-13 | 2021-05-13 | 153 | 0d |  |
| 155 | 1.7.2.16 | Pump Down and Leak Check Exit Beamline (ensure isolation valve is closed) |  | 5d | 2021-05-14 | 2021-05-20 | 154 | 0d |  |
| 156 | 1.7.2.17 | Complete (2A) Survey and Alignment of Correctors and Shielded Beamline |  | 5d | 2021-05-21 | 2021-05-27 | 155 | 89d |  |

| ID | WBS | Task | Type | Duration | Start | Finish | Predecessors | Total slack | Free slack |
| --- | --- | --- | --- | --- | --- | --- | --- | --- | --- |
| 157 | 1.8 | **Big Bite Equipment** |  | 23d | 2021-05-21 | 2021-06-23 |  | 0d |  |
| 158 | 1.8.1 | Move Big Bite Tracks From Right to Left Side of Pivot (S&A new position) |  | 5d | 2021-05-21 | 2021-05-27 | 133, 155 | 0d |  |
| 159 | 1.8.2 | Install Big Bite Stand On Pivot (see procedure) |  | 1d | 2021-05-28 | 2021-05-28 | 158 | 0d |  |
| 160 | 1.8.3 | Survey Pivot Stand Height and Position During Motion |  | 1d | 2021-06-01 | 2021-06-01 | 159 | 0d |  |
| 161 | 1.8.4 | Install Big Bite Craddle on Pivot Stand and Check Motion |  | 1d | 2021-06-02 | 2021-06-02 | 160 | 0d |  |
| 162 | 1.8.5 | Install Big Bite Magnat on Pivot Stand |  | 2d | 2021-06-03 | 2021-06-04 | 161 | 0d |  |
| 163 | 1.8.6 | Survey and Align Big Bite Magnet (2A) |  | 1d | 2021-06-07 | 2021-06-07 | 162 | 64d | 0d |
| 164 | 1.8.7 | Connect Power Leads To Big Bite Magnet |  | 1d | 2021-06-08 | 2021-06-08 | 163 | 64d | 0d |
| 165 | 1.8.8 | Connect Temp Sensors and Electronics |  | 3d | 2021-06-09 | 2021-06-11 | 164 | 64d | 0d |
| 166 | 1.8.9 | Connect LCW |  | 1d | 2021-06-14 | 2021-06-14 | 165 | 64d | 0d |
| 167 | 1.8.10 | Install Guards |  | 3d | 2021-06-15 | 2021-06-17 | 166 | 64d | 0d |
| 168 | 1.8.11 | Conduct Low Power Testing |  | 1d | 2021-06-18 | 2021-06-18 | 167 | 64d | 0d |
| 169 | 1.8.12 | Install Sieve Plate |  | 1d | 2021-06-21 | 2021-06-21 | 168 | 64d | 0d |
| 170 | 1.8.13 | Survey Sieve Plate |  | 2d | 2021-06-22 | 2021-06-23 | 169 | 64d | 0d |
| 171 | 1.9 | **Big Bite Detector Package** |  | 20d | 2021-06-07 | 2021-07-02 |  | 0d |  |
| 172 | 1.9.1 | Disconnect Big Bite Equipment Racks In TED (remaining) |  | 2d | 2021-06-07 | 2021-06-08 | 162 | 0d |  |
| 173 | 1.9.2 | Remaining Big Bite Equipment Ready to Transport to Hall | milestone | 0d | 2021-06-08 | 2021-06-08 | 172 | 82d |  |
| 174 | 1.9.3 | Transport Big Bite Equipment Racks To Hall |  | 1d | 2021-06-09 | 2021-06-09 | 172 | 0d |  |
| 175 | 1.9.4 | Transport Big Bite Detectors To Hall |  | 1d | 2021-06-10 | 2021-06-10 | 174 | 0d |  |
| 176 | 1.9.5 | Transport Big Bite Lockers and Supporting Equipment To Hall |  | 1d | 2021-06-11 | 2021-06-11 | 175 | 0d |  |
| 177 | 1.9.6 | Install Extension on Big Bite Carriage |  | 1d | 2021-06-24 | 2021-06-24 | 170, 176 | 64d | 0d |
| 178 | 1.9.7 | Install Detector on Carriage |  | 1d | 2021-06-25 | 2021-06-25 | 177 | 64d | 0d |
| 179 | 1.9.8 | Install Big Bite Electronics Shielding Hut |  | 2d | 2021-06-28 | 2021-06-29 | 178 | 64d | 0d |
| 180 | 1.9.9 | Install Big Bite Equipment Racks |  | 3d | 2021-06-30 | 2021-07-02 | 179 | 64d | 0d |
| 181 | 1.9.10 | Connect Electronics in Big Bite Equipment Racks (Collaboration) | milestone | 0d | 2021-07-02 | 2021-07-02 | 180 | 64d |  |

| ID | WBS | Task | Type | Duration | Start | Finish | Predecessors | Total slack |
| --- | --- | --- | --- | --- | --- | --- | --- | --- |
| 182 | 1.10 | **SBS Equipment** |  | 79d | 2021-06-14 | 2021-10-01 |  | 0d |
| 183 | 1.10.1 | **Disassemble Counterweight Assembly In Test Lab** |  | 5d | 2021-06-14 | 2021-06-18 |  | 0d |
| 184 | 1.10.1.1 | Disconnect Hydraulic Positioning System |  | 1d | 2021-06-14 | 2021-06-14 | 176 | 0d |
| 185 | 1.10.1.2 | Disassemble Counterweight Steel and Weldment |  | 1d | 2021-06-15 | 2021-06-15 | 184 | 0d |
| 186 | 1.10.1.3 | Lay Counterweight Steel Down Flat |  | 1d | 2021-06-16 | 2021-06-16 | 185 | 0d |
| 187 | 1.10.1.4 | Disassemble Floor Plates |  | 1d | 2021-06-17 | 2021-06-17 | 186 | 0d |
| 188 | 1.10.1.5 | Remaining SBS Equipment Ready to Transport to Hall | milestone | 0d | 2021-06-17 | 2021-06-17 | 187 | 75d |
| 189 | 1.10.1.6 | Prep Equipment and Material For Transporting To Hall |  | 1d | 2021-06-18 | 2021-06-18 | 187 | 0d |
| 190 | 1.10.2 | **Transport 48D48 Magnet Steel and Counterweight To Hall A** |  | 9d | 2021-06-21 | 2021-07-01 |  | 0d |
| 191 | 1.10.2.1 | Clear Floor Space In Test Lab Needed To Load Steel |  | 1d | 2021-06-21 | 2021-06-21 | 189 | 0d |
| 192 | 1.10.2.2 | Clear Floor Space For Delivering Steel In The Hall |  | 1d | 2021-06-22 | 2021-06-22 | 191 | 0d |
| 193 | 1.10.2.3 | Transport Magnet Steel and Counterweight Assembly To Hall |  | 3d | 2021-06-23 | 2021-06-25 | 192 | 0d |
| 194 | 1.10.2.4 | Transport Hydraulic Positioning System To Hall |  | 2d | 2021-06-28 | 2021-06-29 | 193 | 0d |
| 195 | 1.10.2.5 | Transport SBS Lockers and Remaining Equipment To Hall |  | 2d | 2021-06-30 | 2021-07-01 | 194 | 0d |
| 196 | 1.10.3 | **Install 48D48 Magnet and Counterweight Assembly** |  | 48d | 2021-07-02 | 2021-09-08 |  | 0d |
| 197 | 1.10.3.1 | Survey and Install SBS Floor Plates |  | 5d | 2021-07-02 | 2021-07-09 | 195 | 0d |
| 198 | 1.10.3.2 | Install Counterweight Assembly on Floor Plates |  | 2d | 2021-07-12 | 2021-07-13 | 197 | 0d |
| 199 | 1.10.3.3 | Install Hillman Rollers |  | 1d | 2021-07-14 | 2021-07-14 | 198 | 0d |
| 200 | 1.10.3.4 | Install Lifting Jacks and Springs |  | 1d | 2021-07-15 | 2021-07-15 | 199 | 0d |
| 201 | 1.10.3.5 | Connect Hydraulic Hoses and Pumps |  | 1d | 2021-07-16 | 2021-07-16 | 200 | 0d |
| 202 | 1.10.3.6 | Connect Hydraulic Electronics |  | 2d | 2021-07-19 | 2021-07-20 | 201 | 0d |
| 203 | 1.10.3.7 | Check and Adjust Hydraulic Pumps and Controls |  | 2d | 2021-07-21 | 2021-07-22 | 202 | 0d |
| 204 | 1.10.3.8 | Install Positioning Actuators |  | 1d | 2021-07-23 | 2021-07-23 | 203 | 0d |
| 205 | 1.10.3.9 | Connect Power and Test Acuators |  | 2d | 2021-07-26 | 2021-07-27 | 204 | 0d |
| 206 | 1.10.3.10 | Adjust Actuators and Limit Switches |  | 2d | 2021-07-28 | 2021-07-29 | 205 | 0d |
| 207 | 1.10.3.11 | Assemble 48D48 Magnet On Weldment (see procedure) |  | 3d | 2021-07-30 | 2021-08-03 | 206 | 0d |
| 208 | 1.10.3.12 | Test SBS and Counterweight Motion and Controls |  | 2d | 2021-08-04 | 2021-08-05 | 207 | 0d |
| 209 | 1.10.3.13 | Install Field Clamps and Sieve Plates |  | 1d | 2021-08-06 | 2021-08-06 | 208 | 0d |
| 210 | 1.10.3.14 | Move SBS Into Starting Position |  | 1d | 2021-08-09 | 2021-08-09 | 209 | 0d |
| 211 | 1.10.3.15 | Survey and Align SBS (2A) |  | 2d | 2021-08-10 | 2021-08-11 | 210 | 0d |
| 212 | 1.10.3.16 | Connect LCW to SBS |  | 3d | 2021-08-12 | 2021-08-16 | 211 | 0d |
| 213 | 1.10.3.17 | Connect Power Leads To Magnet |  | 2d | 2021-08-17 | 2021-08-18 | 212 | 0d |
| 214 | 1.10.3.18 | Connect Temp Sensors and Electronics |  | 3d | 2021-08-19 | 2021-08-23 | 213 | 0d |
| 215 | 1.10.3.19 | Install Guards |  | 7d | 2021-08-24 | 2021-09-01 | 214 | 0d |
| 216 | 1.10.3.20 | Conduct Low Power Testing |  | 1d | 2021-09-02 | 2021-09-02 | 215 | 0d |
| 217 | 1.10.3.21 | Interface FSD Interlocks |  | 1d | 2021-09-03 | 2021-09-03 | 216 | 0d |
| 218 | 1.10.3.22 | Final Survey and Alignment of SBS (2B) |  | 3d | 2021-09-06 | 2021-09-08 | 217 | 0d |

| ID | WBS | Task | Type | Duration | Start | Finish | Predecessors | Total slack | Free slack | Constraint |
| --- | --- | --- | --- | --- | --- | --- | --- | --- | --- | --- |
| 219 | 1.10.4 | **Transport and Install GeN-RP Detector** |  | 40d | 2021-08-09 | 2021-10-01 |  | 0d |  |  |
| 220 | 1.10.4.1 | Transport Detector Parts to Hall |  | 2d | 2021-08-09 | 2021-08-10 | 209 | 0d |  |  |
| 221 | 1.10.4.2 | Assemble Detector Parts Inside Hall |  | 7d | 2021-08-11 | 2021-08-19 | 220 | 0d |  |  |
| 222 | 1.10.4.3 | Install Detector on SBS Magnet |  | 5d | 2021-08-20 | 2021-08-26 | 221 | 0d |  |  |
| 223 | 1.10.4.4 | Begin Connecting GeN-RP Electronic - Detector End | milestone | 0d | 2021-08-26 | 2021-08-26 | 222 | 0d |  |  |
| 224 | 1.10.4.5 | Connect GeN-RP Electronics and Testing |  | 26d | 2021-08-27 | 2021-10-01 | 223 | 0d |  |  |
| 225 | 1.10.5 | **Transport and Install HCAL** |  | 40d | 2021-08-09 | 2021-10-01 |  | 0d |  |  |
| 226 | 1.10.5.1 | Layout HCAL Floor Plates |  | 1d | 2021-08-09 | 2021-08-09 | 209 | 0d |  |  |
| 227 | 1.10.5.2 | Disassemble HCAL Electronics In Test Lab |  | 1d | 2021-08-10 | 2021-08-10 | 226 | 0d |  |  |
| 228 | 1.10.5.3 | Disassemble HCAL Sub-Assemblies In Test Lab |  | 1d | 2021-08-11 | 2021-08-11 | 227 | 0d |  |  |
| 229 | 1.10.5.4 | Transport Electronic Rack To Hall |  | 2d | 2021-08-12 | 2021-08-13 | 228 | 0d |  |  |
| 230 | 1.10.5.5 | Transport Sub-Assemblies To Hall |  | 2d | 2021-08-16 | 2021-08-17 | 229 | 0d |  |  |
| 231 | 1.10.5.6 | Install HCAL Frame/Support Structure |  | 1d | 2021-08-18 | 2021-08-18 | 230 | 0d |  |  |
| 232 | 1.10.5.7 | Install HCAL Modules on Support Structure |  | 1d | 2021-08-19 | 2021-08-19 | 231 | 0d |  |  |
| 233 | 1.10.5.8 | Install Lead Wall |  | 1d | 2021-08-20 | 2021-08-20 | 232 | 0d |  |  |
| 234 | 1.10.5.9 | Install Work Access Platform |  | 1d | 2021-08-23 | 2021-08-23 | 233 | 0d |  |  |
| 235 | 1.10.5.10 | Install HCAL Equipment Racks Shielding Hut (local) |  | 1d | 2021-08-24 | 2021-08-24 | 234 | 0d |  |  |
| 236 | 1.10.5.11 | Install HCAL Equipment Racks (local) |  | 2d | 2021-08-25 | 2021-08-26 | 235 | 0d |  |  |
| 237 | 1.10.5.12 | Begin Connecting HCAL Electronics - Detector End (collaboration) | milestone | 0d | 2021-08-26 | 2021-08-26 | 236 | 0d |  |  |
| 238 | 1.10.5.13 | Connect HCAL Electronics and Testing |  | 26d | 2021-08-27 | 2021-10-01 | 237 | 0d |  |  |
| 239 | 1.11 | **Final Preparations** |  | 256d? | 2020-09-21 | 2021-10-01 |  | 0d |  |  |
| 240 | 1.11.1 | Cooldown L-HRS |  | 36d | 2021-07-12 | 2021-08-30 | 102 | 24d |  | start no earlier than 2021-07-12 |
| 241 | 1.11.2 | Check for Proper Function on All Temp. Sensor (BB, SBS, and Correctors) |  | 10d | 2021-08-24 | 2021-09-06 | 214 | 4d | 0d |  |
| 242 | 1.11.3 | Make Sure Proper Ion Chamber are Installed |  | 2d | 2021-09-09 | 2021-09-10 | 218 | 12d | 0d |  |
| 243 | 1.11.4 | Check FSD Interfaces |  | 3d | 2021-09-13 | 2021-09-15 | 242 | 12d |  |  |
| 244 | 1.11.5 | Final Pumpdown and Leak Check Entrance Beamline |  | 5d | 2021-09-09 | 2021-09-15 | 218 | 0d |  |  |
| 245 | 1.11.6 | Final Pumpdown and Leak Check Exit Beamline |  | 5d | 2021-09-16 | 2021-09-22 | 244 | 7d |  |  |
| 246 | 1.11.7 | Final Pumpdown and Leak Check L-HRS |  | 5d | 2021-09-16 | 2021-09-22 | 244 | 0d |  |  |
| 247 | 1.11.8 | Final Pumpdown and Leak Check of Target Chamber (Target Group) |  | 3d | 2021-09-23 | 2021-09-27 | 246 | 0d |  |  |
| 248 | 1.11.9 | Final Survey and Align All SBS Equipment (2B) |  | 5d | 2021-09-23 | 2021-09-29 | 246 | 2d |  |  |
| 249 | 1.11.10 | Dial In The Cryo System |  | 4d | 2021-09-28 | 2021-10-01 | 247 | 0d |  |  |
| 250 | 1.11.11 | Test All Magnets and Power Supplies To Full Current |  | 15d | 2021-09-07 | 2021-09-27 | 241 | 4d |  |  |
| 251 | 1.11.12 | Remove Excessive Equipment From Hall |  | 26d | 2021-08-27 | 2021-10-01 | 236 | 0d |  |  |
| 252 | 1.11.13 | Complete Pre-Beam Checklist - Installation Complete | milestone | 0d | 2021-10-01 | 2021-10-01 | 250, 251, 238, 224 | 0d |  |  |

| ID | WBS | Task | Duration | Start | Finish | Total slack |
| --- | --- | --- | --- | --- | --- | --- |
| 255 | 1.11.14 | **ADDITIONAL TASK NOT YET SCHEDULED:** | 1d? | 2020-09-21 | 2020-09-21 | 255d |
| 256 | 1.11.14.1 | Renovate Hall A Counting House (coordinate with Ole) | 1d? | 2020-09-21 | 2020-09-21 | 255d |
| 257 | 1.11.14.2 | Replace LQ2 Power Supply with RQ2 Power Supply (coordinate with Jack) | 1d? | 2020-09-21 | 2020-09-21 | 255d |
| 258 | 1.11.14.3 | Replace the LD1 Multiplexer with the one from RD1 (coordinate with Jack) | 1d? | 2020-09-21 | 2020-09-21 | 255d |
| 259 | 1.11.14.4 | Installation of Fiber Optic Cables From Hall to CH [FML per Alex request] | 1d? | 2020-09-21 | 2020-09-21 | 255d |
